# PEP_HOL1121_REV(03-08-16)

Schedule from MS Project, 2016-08-15 to 2021-05-19.
Microsoft

## Calendars

- Estándar: Mon-Fri 09:00-13:00, 15:00-19:00; Sat-Sun off. Exceptions (off unless hours are given): 2016-10-03 to 2016-10-07 (Feriado Octubre), 2016-12-26 to 2016-12-30 (Navidad), 2017-04-10 to 2017-04-14 (Feriado Semana santa 2017), 2017-05-01 (Feriado día T), 2017-09-15 (Día Independencia), 2017-10-02 to 2017-10-06 (Feriado Semana Octubre 2017), 2017-12-25 to 2017-12-29 (Navidad), 2018-03-26 to 2018-03-30 (Feriado Semana Santa 2018), 2018-05-01 (Feriado dia T), 2018-10-01 to 2018-10-05 (Feriado Semana Octubre 2018), 2018-12-24 to 2018-12-31 (Navidad), 2019-04-15 to 2019-04-19 (Feriado Semana Santa 2019), 2019-05-01 (Feriado día T), 2019-10-01 to 2019-10-04 (Feriado Octubre 2019), 2019-12-23 to 2019-12-31 (Navidad), 2020-04-06 to 2020-04-10 (Feriado Semana Santa 2020), 2020-04-14 (14 Abril), 2020-05-01 (Feriado día T), 2020-09-15 (Día Independencia), 2020-10-05 to 2020-10-09 (Feriado octubre 2020), 2020-12-24 to 2020-12-31 (Navidad).

## Schedule

| ID | WBS | Task | Duration | Start | Finish | Predecessors | Total slack | Free slack | Constraint | Cost |
| --- | --- | --- | --- | --- | --- | --- | --- | --- | --- | --- |
| 1 | 1 | **PLAN DE EJECUCIÓN DEL PROYECTO (HO-L1121): PROGRAMA DE INTEGRACIÓN VIAL REGIONAL II** | 1163d | 2016-08-15 | 2021-05-19 |  | 0d |  |  | 75,000,000 |
| 2 | 1.1 | **COMPONENTE 1: MEJORAMIENTO DE TRAMOS VIALES DE INTEGRACIóN** | 1068d | 2016-08-15 | 2021-01-06 |  | 95d |  |  | 73,250,000 |
| 3 | 1.1.1 | **Obras** | 1043d | 2016-09-19 | 2021-01-06 |  | 95d |  |  | 68,425,000 |
| 4 | 1.1.1.1 | **Corredor Logístico Carretera CA-5 Norte, La Barca- Pimienta. Lote A: La Barca- Potrerillos (18 meses). Lote B: Potrerillos- Pimienta (12 meses).** | 679d | 2016-09-26 | 2019-07-11 |  | 147d |  |  | 43,455,000 |
| 5 | 1.1.1.1.1 | **Proceso de Contratación** | 161d | 2016-09-26 | 2017-05-30 |  | 244d |  |  |  |
| 6 | 1.1.1.1.1.1 | Preparación borrador documentos de licitación | 12d | 2016-09-26 | 2016-10-18 | 234SS+30d | 244d | 0d | start no earlier than 2016-09-19 |  |
| 7 | 1.1.1.1.1.2 | Envio de documento en borrador al BID | 3d | 2016-10-19 | 2016-10-21 | 6 | 244d | 0d |  |  |
| 8 | 1.1.1.1.1.3 | Respuesta del BID al borrador del Documento de Licitación | 5d | 2016-10-24 | 2016-10-28 | 7 | 244d | 0d |  |  |
| 9 | 1.1.1.1.1.4 | Incorporación observaciones al documentos de licitación | 3d | 2016-10-31 | 2016-11-02 | 8 | 244d | 0d |  |  |
| 10 | 1.1.1.1.1.5 | Solicitud de revisión | 3d | 2016-11-03 | 2016-11-07 | 9 | 244d | 0d |  |  |
| 11 | 1.1.1.1.1.6 | Revisión aprobada | 5d | 2016-11-08 | 2016-11-14 | 10 | 244d | 0d |  |  |
| 12 | 1.1.1.1.1.7 | Convocatoria pública a participar (Llamado a Licitación) | 2d | 2016-11-15 | 2016-11-16 | 11 | 244d | 0d |  |  |
| 13 | 1.1.1.1.1.8 | Preparacion de ofertas | 39d | 2016-11-17 | 2017-01-17 | 12 | 244d | 0d |  |  |
| 14 | 1.1.1.1.1.9 | Recepción de ofertas y apertura de sobres | 1d | 2017-01-18 | 2017-01-18 | 13 | 244d | 0d |  |  |
| 15 | 1.1.1.1.1.10 | Evaluación de ofertas | 15d | 2017-01-19 | 2017-02-08 | 14 | 244d | 0d |  |  |
| 16 | 1.1.1.1.1.11 | Solicitud de no objeción (Informe de Evaluación) | 5d | 2017-02-09 | 2017-02-15 | 15 | 244d | 0d |  |  |
| 17 | 1.1.1.1.1.12 | No objeción del BID | 5d | 2017-02-16 | 2017-02-22 | 16 | 244d | 0d |  |  |
| 18 | 1.1.1.1.1.13 | Notificación a oferentes | 7d | 2017-02-23 | 2017-03-03 | 17 | 244d | 0d |  |  |
| 19 | 1.1.1.1.1.14 | Negociacion de Contrato | 10d | 2017-03-06 | 2017-03-17 | 18 | 244d | 0d |  |  |
| 20 | 1.1.1.1.1.15 | Publicación de la adjudicación lote A | 2d | 2017-03-20 | 2017-03-21 | 19 | 244d | 23d |  |  |
| 21 | 1.1.1.1.1.16 | Publicación de la adjudicación lote B | 2d | 2017-03-20 | 2017-03-21 | 19 | 596d | 23d |  |  |
| 22 | 1.1.1.1.1.17 | Suscripción del contrato lote A | 5d | 2017-05-02 | 2017-05-08 | 20, 599 | 221d | 0d |  |  |
| 23 | 1.1.1.1.1.18 | Suscripción del contrato lote B | 5d | 2017-05-02 | 2017-05-08 | 599, 21 | 573d | 0d |  |  |
| 24 | 1.1.1.1.1.19 | Solicitud y aprobacion de garantías lote A | 15d | 2017-05-09 | 2017-05-29 | 22 | 221d | 0d |  |  |
| 25 | 1.1.1.1.1.20 | Solicitud y aprobacion de garantías lote B | 15d | 2017-05-09 | 2017-05-29 | 23 | 573d | 0d |  |  |
| 26 | 1.1.1.1.1.21 | Envío de contrato firmado al BID lote A | 2d | 2017-05-09 | 2017-05-10 | 22 | 986d |  |  |  |
| 27 | 1.1.1.1.1.22 | Envío de contrato firmado al BID lote B | 2d | 2017-05-09 | 2017-05-10 | 23 | 986d |  |  |  |
| 28 | 1.1.1.1.1.23 | Orden de Inicio lote A | 1d | 2017-05-30 | 2017-05-30 | 24, 121FS-70d | 221d | 0d |  |  |
| 29 | 1.1.1.1.1.24 | Orden de Inicio lote B | 1d | 2017-05-30 | 2017-05-30 | 121FS-70d, 25 | 573d | 0d |  |  |
| 30 | 1.1.1.1.2 | Ejecución Construcción lote A: La Barca- Potrerillos | 360d | 2017-05-31 | 2018-11-15 | 28 | 221d | 0d |  |  |

| ID | WBS | Task | Type | Duration | Start | Finish | Predecessors | Total slack | Free slack | Cost |
| --- | --- | --- | --- | --- | --- | --- | --- | --- | --- | --- |
| 31 | 1.1.1.1.3 | **Estimaciones de Pago** |  | 532d | 2017-05-11 | 2019-07-11 |  | 0d |  | 33,447,636 |
| 32 | 1.1.1.1.3.1 | Pago del anticipo | manual | 2d | 2017-05-11 | 2017-05-12 |  |  |  | 6,689,527.18 |
| 33 | 1.1.1.1.3.2 | Estimación 1 | manual | 2d | 2017-07-10 | 2017-07-11 | 32FS+40d |  |  | 372,794.25 |
| 34 | 1.1.1.1.3.3 | Estimación 2 | manual | 2d | 2017-08-09 | 2017-08-10 | 33FS+20d |  |  | 556,113.04 |
| 35 | 1.1.1.1.3.4 | Estimación 3 | manual | 2d | 2017-09-08 | 2017-09-11 | 34FS+20d |  |  | 749,355.42 |
| 36 | 1.1.1.1.3.5 | Estimación 4 |  | 2d | 2017-10-18 | 2017-10-19 | 35FS+20d | 454d | 0d | 1,727,774.58 |
| 37 | 1.1.1.1.3.6 | Estimación 5 |  | 2d | 2017-11-17 | 2017-11-20 | 36FS+20d | 454d | 0d | 3,029,252.95 |
| 38 | 1.1.1.1.3.7 | Estimación 6 |  | 2d | 2018-01-23 | 2018-01-24 | 37FS+40d | 454d | 0d | 2,833,901.65 |
| 39 | 1.1.1.1.3.8 | Estimación 7 |  | 2d | 2018-02-22 | 2018-02-23 | 38FS+20d | 454d | 0d | 2,516,875.3 |
| 40 | 1.1.1.1.3.9 | Estimación 8 |  | 2d | 2018-04-02 | 2018-04-03 | 39FS+20d | 454d | 0d | 2,852,342.46 |
| 41 | 1.1.1.1.3.10 | Estimación 9 |  | 2d | 2018-05-03 | 2018-05-04 | 40FS+20d | 454d | 0d | 2,562,745.98 |
| 42 | 1.1.1.1.3.11 | Estimación 10 |  | 2d | 2018-06-04 | 2018-06-05 | 41FS+20d | 454d | 0d | 1,450,634.76 |
| 43 | 1.1.1.1.3.12 | Estimación 11 |  | 2d | 2018-07-04 | 2018-07-05 | 42FS+20d | 454d | 0d | 944,101.36 |
| 44 | 1.1.1.1.3.13 | Estimación 12 |  | 2d | 2018-08-03 | 2018-08-06 | 43FS+20d | 454d | 0d | 917,449.21 |
| 45 | 1.1.1.1.3.14 | Estimación 13 |  | 2d | 2018-09-04 | 2018-09-05 | 44FS+20d | 454d | 0d | 1,579,863.65 |
| 46 | 1.1.1.1.3.15 | Estimación 14 |  | 2d | 2018-10-11 | 2018-10-12 | 45FS+20d | 454d | 0d | 1,404,703.55 |
| 47 | 1.1.1.1.3.16 | Estimación 15 |  | 2d | 2018-11-12 | 2018-11-13 | 46FS+20d | 454d | 0d | 1,438,962.39 |
| 48 | 1.1.1.1.3.17 | Estimación 16 |  | 2d | 2019-01-17 | 2019-01-18 | 47FS+40d | 454d | 0d | 1,127,869.83 |
| 49 | 1.1.1.1.3.18 | Estimación 17 |  | 2d | 2019-02-18 | 2019-02-19 | 48FS+20d | 454d | 0d | 489,605.98 |
| 50 | 1.1.1.1.3.19 | Estimación 18 |  | 2d | 2019-05-09 | 2019-05-10 | 49FS+50d | 454d | 0d | 143,749.32 |
| 51 | 1.1.1.1.3.20 | Estimación 19 |  | 2d | 2019-06-10 | 2019-06-11 | 50FS+20d | 454d | 0d | 41,363.67 |
| 52 | 1.1.1.1.3.21 | Estimación 20 |  | 2d | 2019-07-10 | 2019-07-11 | 51FS+20d | 454d |  | 18,649.47 |
| 53 | 1.1.1.1.4 | Ejecución Construcción lote B: Potrerillos- Pimienta |  | 245d | 2017-05-31 | 2018-05-31 | 29 | 573d | 481d |  |
| 54 | 1.1.1.1.5 | **Estimaciones de Pago** |  | 306d | 2017-05-11 | 2018-08-06 |  | 0d |  | 10,007,364 |
| 55 | 1.1.1.1.5.1 | Pago del anticipo | manual | 2d | 2017-05-11 | 2017-05-12 |  |  |  | 2,001,637.06 |
| 56 | 1.1.1.1.5.2 | Estimación 1 | manual | 2d | 2017-07-10 | 2017-07-11 | 55FS+40d |  |  | 489,071.42 |
| 57 | 1.1.1.1.5.3 | Estimación 2 | manual | 2d | 2017-08-09 | 2017-08-10 | 56FS+20d |  |  | 706,809.36 |
| 58 | 1.1.1.1.5.4 | Estimación 3 | manual | 2d | 2017-09-08 | 2017-09-11 | 57FS+20d |  |  | 760,667.87 |
| 59 | 1.1.1.1.5.5 | Estimación 4 |  | 2d | 2017-10-18 | 2017-10-19 | 58FS+20d | 680d | 0d | 760,667.87 |
| 60 | 1.1.1.1.5.6 | Estimación 5 |  | 2d | 2017-11-17 | 2017-11-20 | 59FS+20d | 680d | 0d | 760,667.87 |
| 61 | 1.1.1.1.5.7 | Estimación 6 |  | 2d | 2018-01-23 | 2018-01-24 | 60FS+40d | 680d | 0d | 738,755.39 |
| 62 | 1.1.1.1.5.8 | Estimación 7 |  | 2d | 2018-02-22 | 2018-02-23 | 61FS+20d | 680d | 0d | 751,828.33 |
| 63 | 1.1.1.1.5.9 | Estimación 8 |  | 2d | 2018-04-02 | 2018-04-03 | 62FS+20d | 680d | 0d | 791,215.86 |
| 64 | 1.1.1.1.5.10 | Estimación 9 |  | 2d | 2018-05-03 | 2018-05-04 | 63FS+20d | 680d | 0d | 830,603.4 |
| 65 | 1.1.1.1.5.11 | Estimación 10 |  | 2d | 2018-06-04 | 2018-06-05 | 64FS+20d | 680d | 0d | 665,730.24 |
| 66 | 1.1.1.1.5.12 | Estimación 11 |  | 2d | 2018-07-04 | 2018-07-05 | 65FS+20d | 680d | 0d | 414,345.09 |
| 67 | 1.1.1.1.5.13 | Estimación 12 |  | 2d | 2018-08-03 | 2018-08-06 | 66FS+20d | 680d |  | 335,364.24 |

| ID | WBS | Task | Duration | Start | Finish | Predecessors | Total slack | Free slack | Constraint | Cost |
| --- | --- | --- | --- | --- | --- | --- | --- | --- | --- | --- |
| 68 | 1.1.1.2 | **Construcción de obras Corredor Turístico Libramiento El Progreso (siempre que cumpla con los criterios de elegibilidad)** | 675d | 2018-04-02 | 2021-01-06 |  | 61d |  |  | 21,000,000 |
| 69 | 1.1.1.2.1 | **Proceso de Contratación** | 154d | 2018-04-02 | 2018-11-09 |  | 61d |  |  |  |
| 70 | 1.1.1.2.1.1 | Preparación borrador documentos de licitación | 12d | 2018-04-02 | 2018-04-17 |  | 61d | 0d | start no earlier than 2018-04-02 |  |
| 71 | 1.1.1.2.1.2 | Envio de documento en borrador al BID | 3d | 2018-04-18 | 2018-04-20 | 70 | 61d | 0d |  |  |
| 72 | 1.1.1.2.1.3 | Respuesta del BID al borrador del Documento de Licitación | 5d | 2018-04-23 | 2018-04-27 | 71 | 61d | 0d |  |  |
| 73 | 1.1.1.2.1.4 | Incorporación observaciones al documentos de licitación | 3d | 2018-04-30 | 2018-05-03 | 72 | 61d | 0d |  |  |
| 74 | 1.1.1.2.1.5 | Solicitud de no objeción al BID | 3d | 2018-05-04 | 2018-05-08 | 73 | 61d | 0d |  |  |
| 75 | 1.1.1.2.1.6 | No objeción del BID | 5d | 2018-05-09 | 2018-05-15 | 74 | 61d | 0d |  |  |
| 76 | 1.1.1.2.1.7 | Convocatoria pública a participar (Llamado a Licitación) | 2d | 2018-05-16 | 2018-05-17 | 75 | 61d | 0d |  |  |
| 77 | 1.1.1.2.1.8 | Preparacion de ofertas | 32d | 2018-05-18 | 2018-07-02 | 76 | 61d | 0d |  |  |
| 78 | 1.1.1.2.1.9 | Recepción de ofertas y apertura de sobres | 1d | 2018-07-03 | 2018-07-03 | 77 | 61d | 0d |  |  |
| 79 | 1.1.1.2.1.10 | Evaluación de ofertas | 22d | 2018-07-04 | 2018-08-02 | 78 | 61d | 0d |  |  |
| 80 | 1.1.1.2.1.11 | Solicitud de no objeción (Informe de Evaluación) | 5d | 2018-08-03 | 2018-08-09 | 79 | 61d | 0d |  |  |
| 81 | 1.1.1.2.1.12 | No objeción del BID | 5d | 2018-08-10 | 2018-08-16 | 80 | 61d | 0d |  |  |
| 82 | 1.1.1.2.1.13 | Notificación a oferentes | 7d | 2018-08-17 | 2018-08-27 | 81 | 61d | 0d |  |  |
| 83 | 1.1.1.2.1.14 | Negociacion de Contrato | 10d | 2018-08-28 | 2018-09-10 | 82 | 61d | 0d |  |  |
| 84 | 1.1.1.2.1.15 | Publicación de la adjudicación y carta de adjudicacion | 2d | 2018-09-11 | 2018-09-12 | 83 | 61d | 0d |  |  |
| 85 | 1.1.1.2.1.16 | Suscripción del contrato | 5d | 2018-09-13 | 2018-09-19 | 84 | 61d | 0d |  |  |
| 86 | 1.1.1.2.1.17 | Solicitud y aprobacion de garantías | 15d | 2018-09-20 | 2018-10-17 | 85 | 61d | 0d |  |  |
| 87 | 1.1.1.2.1.18 | Envío de contrato firmado al BID | 2d | 2018-09-13 | 2018-09-14 | 84 | 651d |  |  |  |
| 88 | 1.1.1.2.1.19 | Orden de Inicio | 1d | 2018-11-09 | 2018-11-09 | 86, 317FS+22d | 45d | 0d |  |  |
| 89 | 1.1.1.2.2 | Ejecución Construcción | 370d | 2018-11-12 | 2020-05-22 | 88, 28 | 45d | 0d |  |  |
| 90 | 1.1.1.2.3 | **Estimaciones de Pago** | 528d | 2018-11-01 | 2021-01-06 |  | 95d |  |  | 21,000,000 |
| 91 | 1.1.1.2.3.1 | Pago del anticipo | 2d | 2018-11-01 | 2018-11-02 | 86FS+10d, 24FS+10d | 95d | 0d |  | 4,000,000 |
| 92 | 1.1.1.2.3.2 | Estimación 1 | 2d | 2019-01-08 | 2019-01-09 | 91FS+40d | 95d | 0d |  | 1,616,814 |
| 93 | 1.1.1.2.3.3 | Estimación 2 | 2d | 2019-02-07 | 2019-02-08 | 92FS+20d | 95d | 0d |  | 773,033 |
| 94 | 1.1.1.2.3.4 | Estimación 3 | 2d | 2019-03-11 | 2019-03-12 | 93FS+20d | 95d | 0d |  | 764,626 |
| 95 | 1.1.1.2.3.5 | Estimación 4 | 2d | 2019-04-10 | 2019-04-11 | 94FS+20d | 95d | 0d |  | 764,626 |
| 96 | 1.1.1.2.3.6 | Estimación 5 | 2d | 2019-05-20 | 2019-05-21 | 95FS+20d | 95d | 0d |  | 773,066 |
| 97 | 1.1.1.2.3.7 | Estimación 6 | 2d | 2019-07-17 | 2019-07-18 | 96FS+40d | 95d | 0d |  | 760,616 |
| 98 | 1.1.1.2.3.8 | Estimación 7 | 2d | 2019-09-27 | 2019-09-30 | 97FS+50d | 95d | 0d |  | 854,219 |
| 99 | 1.1.1.2.3.9 | Estimación 8 | 2d | 2019-11-04 | 2019-11-05 | 98FS+20d | 95d | 0d |  | 894,953 |
| 100 | 1.1.1.2.3.10 | Estimación 9 | 2d | 2019-12-04 | 2019-12-05 | 99FS+20d | 95d | 0d |  | 894,953 |
| 101 | 1.1.1.2.3.11 | Estimación 10 | 2d | 2020-01-14 | 2020-01-15 | 100FS+20d | 95d | 0d |  | 888,228 |
| 102 | 1.1.1.2.3.12 | Estimación 11 | 2d | 2020-02-13 | 2020-02-14 | 101FS+20d | 95d | 0d |  | 888,228 |
| 103 | 1.1.1.2.3.13 | Estimación 12 | 2d | 2020-03-16 | 2020-03-17 | 102FS+20d | 95d | 0d |  | 784,551 |
| 104 | 1.1.1.2.3.14 | Estimación 13 | 2d | 2020-04-23 | 2020-04-24 | 103FS+20d | 95d | 0d |  | 784,551 |
| 105 | 1.1.1.2.3.15 | Estimación 14 | 2d | 2020-05-26 | 2020-05-27 | 104FS+20d | 95d | 0d |  | 1,151,250 |
| 106 | 1.1.1.2.3.16 | Estimación 15 | 2d | 2020-07-23 | 2020-07-24 | 105FS+40d | 95d | 0d |  | 1,158,477 |
| 107 | 1.1.1.2.3.17 | Estimación 16 | 2d | 2020-08-24 | 2020-08-25 | 106FS+20d | 95d | 0d |  | 1,164,662 |
| 108 | 1.1.1.2.3.18 | Estimación 17 | 2d | 2020-09-24 | 2020-09-25 | 107FS+20d | 95d | 0d |  | 1,223,814 |
| 109 | 1.1.1.2.3.19 | Estimación 18 | 2d | 2021-01-05 | 2021-01-06 | 108FS+60d | 95d |  |  | 859,333 |

| ID | WBS | Task | Duration | Start | Finish | Predecessors | Total slack | Free slack | Constraint | Cost |
| --- | --- | --- | --- | --- | --- | --- | --- | --- | --- | --- |
| 110 | 1.1.1.3 | **Firma para la implementación Plan de Reasentamiento La Barca - Pimienta** | 230d | 2016-09-19 | 2017-08-28 |  | 338d |  |  |  |
| 111 | 1.1.1.3.1 | **Proceso de Contratación** | 38d | 2016-09-19 | 2016-11-16 |  | 338d |  |  |  |
| 112 | 1.1.1.3.1.1 | Elaboración de TdeR y de presupuesto | 5d | 2016-09-19 | 2016-09-23 |  | 338d | 0d | start no earlier than 2016-09-19 |  |
| 113 | 1.1.1.3.1.2 | Presentación de propuesta | 5d | 2016-09-26 | 2016-09-30 | 112 | 338d | 0d |  |  |
| 114 | 1.1.1.3.1.3 | Evaluación de propuestas técnicas y de precio | 5d | 2016-10-10 | 2016-10-14 | 113 | 338d | 0d |  |  |
| 115 | 1.1.1.3.1.4 | Invitación a negociación | 2d | 2016-10-17 | 2016-10-18 | 114 | 338d | 0d |  |  |
| 116 | 1.1.1.3.1.5 | Negociación del contrato | 5d | 2016-10-19 | 2016-10-25 | 115 | 338d | 0d |  |  |
| 117 | 1.1.1.3.1.6 | Elaboración de la modificación de contrato | 2d | 2016-10-26 | 2016-10-27 | 116 | 338d | 0d |  |  |
| 118 | 1.1.1.3.1.7 | Solicitud de aprobación contrato a CD | 10d | 2016-10-28 | 2016-11-10 | 117 | 338d | 0d |  |  |
| 119 | 1.1.1.3.1.8 | Suscripción de modificación al contrato | 3d | 2016-11-11 | 2016-11-15 | 118 | 338d | 0d |  |  |
| 120 | 1.1.1.3.1.9 | Orden de Inicio | 1d | 2016-11-16 | 2016-11-16 | 119 | 338d | 0d |  |  |
| 121 | 1.1.1.3.2 | Ejecución de la consultoría | 80d | 2016-11-17 | 2017-03-15 | 120 | 338d | 0d |  |  |
| 122 | 1.1.1.3.3 | **Pagos** | 192d | 2016-11-17 | 2017-08-28 |  | 908d |  |  |  |
| 123 | 1.1.1.3.3.1 | Pago No.1 | 2d | 2016-11-17 | 2016-11-18 | 120 | 908d | 0d |  |  |
| 124 | 1.1.1.3.3.2 | Pago No.2 | 2d | 2016-12-19 | 2016-12-20 | 123FS+20d | 908d | 0d |  |  |
| 125 | 1.1.1.3.3.3 | Pago No.3 | 2d | 2017-02-22 | 2017-02-23 | 124FS+40d | 908d | 0d |  |  |
| 126 | 1.1.1.3.3.4 | Pago No.4 | 2d | 2017-04-28 | 2017-05-02 | 125FS+40d | 908d | 0d |  |  |
| 127 | 1.1.1.3.3.5 | Pago No.5 | 2d | 2017-06-28 | 2017-06-29 | 126FS+40d | 908d | 0d |  |  |
| 128 | 1.1.1.3.3.6 | Pago No.6 | 2d | 2017-08-25 | 2017-08-28 | 127FS+40d | 908d |  |  |  |
| 129 | 1.1.1.4 | **Caracterización Socioeconómica y Elaboración e Implementación Planes de Acción de Reasentamiento (PAR) Proyecto Corredor Turístico Libramiento El Progreso (siempre que cumpla con los criterios de elegibilidad)** | 413d | 2017-04-28 | 2019-01-07 |  | 45d |  |  | 450,000 |
| 130 | 1.1.1.4.1 | **Proceso de Contratación (SBCC)** | 148d | 2017-04-28 | 2017-11-30 |  | 45d |  |  |  |
| 131 | 1.1.1.4.1.1 | Elaboración Anuncio Expresión de Interés | 10d | 2017-04-28 | 2017-05-12 |  | 45d | 0d | start no earlier than 2017-04-28 |  |
| 132 | 1.1.1.4.1.2 | Solicitud de no objeción del BID | 2d | 2017-05-15 | 2017-05-16 | 131 | 45d | 0d |  |  |
| 133 | 1.1.1.4.1.3 | No objeción del BID | 5d | 2017-05-17 | 2017-05-23 | 132 | 45d | 0d |  |  |
| 134 | 1.1.1.4.1.4 | Publicación anuncio con solicitud de expresiones de interés | 1d | 2017-05-24 | 2017-05-24 | 133 | 45d | 0d |  |  |
| 135 | 1.1.1.4.1.5 | Recepcion de Expresiones de Interes | 11d | 2017-05-25 | 2017-06-08 | 134 | 45d | 0d |  |  |
| 136 | 1.1.1.4.1.6 | Análisis de expresiones de interés | 22d | 2017-06-09 | 2017-07-10 | 135 | 934d | 0d |  |  |
| 137 | 1.1.1.4.1.7 | Elaboración de lista corta | 3d | 2017-07-11 | 2017-07-13 | 136 | 934d | 0d |  |  |
| 138 | 1.1.1.4.1.8 | Solicitud de no objeción al BID de lista corta | 1d | 2017-07-14 | 2017-07-14 | 137 | 934d | 0d |  |  |
| 139 | 1.1.1.4.1.9 | No objeción del BID a la lista corta | 5d | 2017-07-17 | 2017-07-21 | 138 | 934d |  |  |  |
| 140 | 1.1.1.4.1.10 | Elaboración de SP, TdeR y de presupuesto | 10d | 2017-06-09 | 2017-06-22 | 135 | 45d | 0d |  |  |
| 141 | 1.1.1.4.1.11 | Solicitud de no objeción al BID SP y Presupuesto | 1d | 2017-06-23 | 2017-06-23 | 140 | 45d | 0d |  |  |
| 142 | 1.1.1.4.1.12 | No objeción del BID al SP y presupuesto | 5d | 2017-06-26 | 2017-06-30 | 141 | 45d | 0d |  |  |
| 143 | 1.1.1.4.1.13 | Notificación de conformación de lista corta | 5d | 2017-07-03 | 2017-07-07 | 142 | 45d | 0d |  |  |
| 144 | 1.1.1.4.1.14 | Remisión de SP a integrantes de la lista corta | 2d | 2017-07-10 | 2017-07-11 | 143 | 45d | 0d |  |  |
| 145 | 1.1.1.4.1.15 | Presentación de propuesta | 32d | 2017-07-12 | 2017-08-24 | 144 | 45d | 0d |  |  |
| 146 | 1.1.1.4.1.16 | Evaluación de propuestas técnicas | 15d | 2017-08-25 | 2017-09-14 | 145 | 45d | 0d |  |  |
| 147 | 1.1.1.4.1.17 | Solicitud de no objeción del BID | 2d | 2017-09-18 | 2017-09-19 | 146 | 45d | 0d |  |  |
| 148 | 1.1.1.4.1.18 | No objeción del BID | 5d | 2017-09-20 | 2017-09-26 | 147 | 45d | 0d |  |  |
| 149 | 1.1.1.4.1.19 | Notificación de resultados a los participantes (Evaluación técnica) | 2d | 2017-09-27 | 2017-09-28 | 148 | 45d | 0d |  |  |
| 150 | 1.1.1.4.1.20 | Apertura de propuestas de precios | 3d | 2017-09-29 | 2017-10-10 | 149 | 45d | 0d |  |  |
| 151 | 1.1.1.4.1.21 | Evaluación combinada de calidad y costo | 5d | 2017-10-11 | 2017-10-17 | 150 | 45d | 0d |  |  |
| 152 | 1.1.1.4.1.22 | Negociación del contrato | 5d | 2017-10-18 | 2017-10-24 | 151 | 45d | 0d |  |  |
| 153 | 1.1.1.4.1.23 | Solicitud de No Objeción al BID a Evaluación combinada y a borrador del contrato negociado | 2d | 2017-10-25 | 2017-10-26 | 152 | 45d | 0d |  |  |
| 154 | 1.1.1.4.1.24 | No objeción | 5d | 2017-10-27 | 2017-11-02 | 153 | 45d | 0d |  |  |
| 155 | 1.1.1.4.1.25 | Publicación de la adjudicación y notificacion al ganador | 2d | 2017-11-03 | 2017-11-06 | 154 | 45d | 0d |  |  |
| 156 | 1.1.1.4.1.26 | Suscripción del contrato | 3d | 2017-11-07 | 2017-11-09 | 155 | 45d | 0d |  |  |
| 157 | 1.1.1.4.1.27 | Presentación de garantía bancarias | 15d | 2017-11-10 | 2017-11-30 | 156 | 846d |  |  |  |
| 158 | 1.1.1.4.1.28 | Envío de contrato firmado al BID y formulario PRISM | 2d | 2017-11-10 | 2017-11-13 | 156 | 859d |  |  |  |
| 159 | 1.1.1.4.1.29 | Orden de Inicio | 1d | 2017-11-10 | 2017-11-10 | 156 | 45d | 0d |  |  |
| 160 | 1.1.1.4.2 | Ejecución de la consultoría | 220d | 2017-11-13 | 2018-10-08 | 159 | 45d | 0d |  |  |

| ID | WBS | Task | Duration | Start | Finish | Predecessors | Total slack | Free slack | Cost |
| --- | --- | --- | --- | --- | --- | --- | --- | --- | --- |
| 161 | 1.1.1.4.3 | **Pagos** | 279d | 2017-11-13 | 2019-01-07 |  | 581d |  | 450,000 |
| 162 | 1.1.1.4.3.1 | Anticipo | 2d | 2017-11-13 | 2017-11-14 | 159 | 581d | 0d | 45,000 |
| 163 | 1.1.1.4.3.2 | Pago No.1 | 2d | 2017-12-13 | 2017-12-14 | 162FS+20d | 581d | 0d | 45,000 |
| 164 | 1.1.1.4.3.3 | Pago No.2 | 2d | 2018-02-16 | 2018-02-19 | 163FS+40d | 581d | 0d | 45,000 |
| 165 | 1.1.1.4.3.4 | Pago No.3 | 2d | 2018-03-20 | 2018-03-21 | 164FS+20d | 581d | 0d | 45,000 |
| 166 | 1.1.1.4.3.5 | Pago No.4 | 2d | 2018-05-25 | 2018-05-28 | 165FS+40d | 581d | 0d | 45,000 |
| 167 | 1.1.1.4.3.6 | Pago No.5 | 2d | 2018-06-26 | 2018-06-27 | 166FS+20d | 581d | 0d | 45,000 |
| 168 | 1.1.1.4.3.7 | Pago No.6 | 2d | 2018-08-23 | 2018-08-24 | 167FS+40d | 581d | 0d | 45,000 |
| 169 | 1.1.1.4.3.8 | Pago No.7 | 2d | 2018-09-24 | 2018-09-25 | 168FS+20d | 581d | 0d | 45,000 |
| 170 | 1.1.1.4.3.9 | Pago No.8 | 2d | 2018-11-28 | 2018-11-29 | 169FS+40d | 581d | 0d | 45,000 |
| 171 | 1.1.1.4.3.10 | Pago No.9 | 1d | 2019-01-07 | 2019-01-07 | 170FS+20d | 581d |  | 45,000 |
| 172 | 1.1.1.5 | **Fideicomiso de apoyo a implementación de Planes de Reasentamiento La Barca-Pimienta** | 305d | 2016-10-31 | 2018-01-30 |  | 808d |  |  |
| 173 | 1.1.1.5.1 | **Proceso de contratación (CD)** | 55d | 2016-10-31 | 2017-01-20 |  | 808d |  |  |
| 174 | 1.1.1.5.1.1 | Elaboración de especificaciones técnicas | 10d | 2016-10-31 | 2016-11-11 | 112FS+20d | 808d | 0d |  |
| 175 | 1.1.1.5.1.2 | Invitación a presentar ofertas | 2d | 2016-11-14 | 2016-11-15 | 174 | 808d | 0d |  |
| 176 | 1.1.1.5.1.3 | Recepción de ofertas | 10d | 2016-11-16 | 2016-11-29 | 175 | 808d | 0d |  |
| 177 | 1.1.1.5.1.4 | Evaluación ofertas | 7d | 2016-11-30 | 2016-12-08 | 176 | 808d | 0d |  |
| 178 | 1.1.1.5.1.5 | Negociación | 5d | 2016-12-09 | 2016-12-15 | 177 | 808d | 0d |  |
| 179 | 1.1.1.5.1.6 | Solicitud de aprobación contrato a CD | 15d | 2016-12-16 | 2017-01-12 | 178 | 808d | 0d |  |
| 180 | 1.1.1.5.1.7 | Suscripción de contrato | 5d | 2017-01-13 | 2017-01-19 | 179 | 808d | 0d |  |
| 181 | 1.1.1.5.1.8 | Orden de inicio | 1d | 2017-01-20 | 2017-01-20 | 180 | 808d | 0d |  |
| 182 | 1.1.1.5.2 | Ejecución de consultoría | 250d | 2017-01-23 | 2018-01-30 | 181 | 808d |  |  |
| 183 | 1.1.1.5.3 | **Pagos** | 192d | 2017-02-20 | 2017-11-30 |  | 846d |  |  |
| 184 | 1.1.1.5.3.1 | Pago 1 | 2d | 2017-02-20 | 2017-02-21 | 181FS+20d | 846d | 0d |  |
| 185 | 1.1.1.5.3.2 | Pago 2 | 2d | 2017-03-22 | 2017-03-23 | 184FS+20d | 846d | 0d |  |
| 186 | 1.1.1.5.3.3 | Pago 3 | 2d | 2017-05-29 | 2017-05-30 | 185FS+40d | 846d | 0d |  |
| 187 | 1.1.1.5.3.4 | Pago 4 | 2d | 2017-06-28 | 2017-06-29 | 186FS+20d | 846d | 0d |  |
| 188 | 1.1.1.5.3.5 | Pago 5 | 2d | 2017-09-25 | 2017-09-26 | 187FS+60d | 846d | 0d |  |
| 189 | 1.1.1.5.3.6 | Pago 6 | 2d | 2017-11-29 | 2017-11-30 | 188FS+40d | 846d |  |  |

| ID | WBS | Task | Duration | Start | Finish | Predecessors | Total slack | Free slack | Cost |
| --- | --- | --- | --- | --- | --- | --- | --- | --- | --- |
| 190 | 1.1.1.6 | **Fideicomiso de apoyo a implementación de Planes de Reasentamiento proyecto Corredor Turístico Libramiento El Progreso (siempre que cumpla con los criterios de elegibilidad)** | 580d | 2017-07-12 | 2019-11-22 |  | 362d |  | 120,000 |
| 191 | 1.1.1.6.1 | **Proceso de contratación (LPN)** | 76d | 2017-07-12 | 2017-11-02 |  | 362d |  |  |
| 192 | 1.1.1.6.1.1 | Elaboración de especificaciones técnicas | 10d | 2017-07-12 | 2017-07-25 | 144 | 362d | 0d |  |
| 193 | 1.1.1.6.1.2 | Preparación de LPN | 5d | 2017-07-26 | 2017-08-01 | 192 | 362d | 0d |  |
| 194 | 1.1.1.6.1.3 | Solicitud de No Objeción del BID de LPN | 2d | 2017-08-02 | 2017-08-03 | 193 | 362d | 0d |  |
| 195 | 1.1.1.6.1.4 | No Objeción | 5d | 2017-08-04 | 2017-08-10 | 194 | 362d | 0d |  |
| 196 | 1.1.1.6.1.5 | Publicación LPN | 2d | 2017-08-11 | 2017-08-14 | 195 | 362d | 0d |  |
| 197 | 1.1.1.6.1.6 | Recepción de ofertas | 22d | 2017-08-15 | 2017-09-13 | 196 | 362d | 0d |  |
| 198 | 1.1.1.6.1.7 | Evaluación ofertas | 15d | 2017-09-14 | 2017-10-12 | 197 | 362d | 0d |  |
| 199 | 1.1.1.6.1.8 | Solicitud de No Objeción a informe de evaluación | 2d | 2017-10-13 | 2017-10-16 | 198 | 362d | 0d |  |
| 200 | 1.1.1.6.1.9 | No Objeción | 5d | 2017-10-17 | 2017-10-23 | 199 | 362d | 0d |  |
| 201 | 1.1.1.6.1.10 | Suscripción de contrato | 5d | 2017-10-24 | 2017-10-30 | 200 | 362d | 0d |  |
| 202 | 1.1.1.6.1.11 | Envío de contrato firmado y formulario Sistem Prism al BID | 2d | 2017-10-31 | 2017-11-01 | 201 | 362d | 0d |  |
| 203 | 1.1.1.6.1.12 | Orden de inicio | 1d | 2017-11-02 | 2017-11-02 | 202 | 362d | 0d |  |
| 204 | 1.1.1.6.2 | Ejecución de consultoría | 370d | 2017-11-03 | 2019-05-14 | 203 | 496d |  |  |
| 205 | 1.1.1.6.3 | **Pagos** | 464d | 2018-01-05 | 2019-11-22 |  | 362d |  | 120,000 |
| 206 | 1.1.1.6.3.1 | Pago 1 | 2d | 2018-01-05 | 2018-01-08 | 203FS+40d | 362d | 0d | 10,000 |
| 207 | 1.1.1.6.3.2 | Pago 2 | 2d | 2018-03-06 | 2018-03-07 | 206FS+40d | 362d | 0d | 10,000 |
| 208 | 1.1.1.6.3.3 | Pago 3 | 2d | 2018-05-11 | 2018-05-14 | 207FS+40d | 362d | 0d | 10,000 |
| 209 | 1.1.1.6.3.4 | Pago 4 | 2d | 2018-07-10 | 2018-07-11 | 208FS+40d | 362d | 0d | 10,000 |
| 210 | 1.1.1.6.3.5 | Pago 5 | 2d | 2018-09-06 | 2018-09-07 | 209FS+40d | 362d | 0d | 10,000 |
| 211 | 1.1.1.6.3.6 | Pago 6 | 2d | 2018-11-12 | 2018-11-13 | 210FS+40d | 362d | 0d | 10,000 |
| 212 | 1.1.1.6.3.7 | Pago 7 | 2d | 2019-01-17 | 2019-01-18 | 211FS+40d | 362d | 0d | 10,000 |
| 213 | 1.1.1.6.3.8 | Pago 8 | 2d | 2019-03-18 | 2019-03-19 | 212FS+40d | 362d | 0d | 10,000 |
| 214 | 1.1.1.6.3.9 | Pago 9 | 2d | 2019-05-23 | 2019-05-24 | 213FS+40d | 362d | 0d | 10,000 |
| 215 | 1.1.1.6.3.10 | Pago 10 | 2d | 2019-07-22 | 2019-07-23 | 214FS+40d | 362d | 0d | 10,000 |
| 216 | 1.1.1.6.3.11 | Pago 11 | 2d | 2019-09-18 | 2019-09-19 | 215FS+40d | 362d | 0d | 10,000 |
| 217 | 1.1.1.6.3.12 | Pago 12 | 2d | 2019-11-21 | 2019-11-22 | 216FS+40d | 362d |  | 10,000 |

| ID | WBS | Task | Duration | Start | Finish | Predecessors | Total slack | Free slack | Constraint | Cost |
| --- | --- | --- | --- | --- | --- | --- | --- | --- | --- | --- |
| 218 | 1.1.1.7 | **Pagos de Implementacion del Plan de Reasentamiento La Barca-Pimienta y las Obras del Corredor Turístico Libramiento El Progreso (siempre que cumpla con los criterios de elegibilidad)** | 818d | 2017-04-20 | 2020-08-20 |  | 182d |  |  | 3,400,000 |
| 219 | 1.1.1.7.1 | Pago 1 | 2d | 2017-04-20 | 2017-04-21 | 121SS+100d | 874d | 0d |  |  |
| 220 | 1.1.1.7.2 | Pago 2 | 2d | 2017-06-20 | 2017-06-21 | 219FS+40d | 874d | 0d |  |  |
| 221 | 1.1.1.7.3 | Pago 3 | 2d | 2017-10-20 | 2017-10-23 | 220FS+80d | 874d |  |  |  |
| 222 | 1.1.1.7.4 | Pago 4 | 2d | 2018-12-04 | 2018-12-05 | 160FS+40d | 182d | 0d |  |  |
| 223 | 1.1.1.7.5 | Pago 5 | 2d | 2019-02-08 | 2019-02-11 | 222FS+40d | 182d | 0d |  | 425,000 |
| 224 | 1.1.1.7.6 | Pago 6 | 2d | 2019-05-15 | 2019-05-16 | 223FS+60d | 182d | 0d |  | 425,000 |
| 225 | 1.1.1.7.7 | Pago 7 | 2d | 2019-07-12 | 2019-07-15 | 224FS+40d | 182d | 0d |  | 425,000 |
| 226 | 1.1.1.7.8 | Pago 8 | 2d | 2019-09-10 | 2019-09-11 | 225FS+40d | 182d | 0d |  | 425,000 |
| 227 | 1.1.1.7.9 | Pago 9 | 2d | 2019-11-13 | 2019-11-14 | 226FS+40d | 182d | 0d |  | 425,000 |
| 228 | 1.1.1.7.10 | Pago 10 | 2d | 2020-01-21 | 2020-01-22 | 227FS+40d | 182d | 0d |  | 425,000 |
| 229 | 1.1.1.7.11 | Pago 11 | 2d | 2020-03-19 | 2020-03-20 | 228FS+40d | 182d | 0d |  | 425,000 |
| 230 | 1.1.1.7.12 | Pago 12 | 2d | 2020-08-19 | 2020-08-20 | 229FS+100d | 182d |  |  | 425,000 |
| 231 | 1.1.2 | **Supervisión** | 964d | 2016-08-15 | 2020-07-28 |  | 199d |  |  | 4,075,000 |
| 232 | 1.1.2.1 | **Supervisión Construcción Carretera CA-5 Norte, La Barca- Pimienta (20 meses)** | 658d | 2016-08-15 | 2019-04-30 |  | 244d |  |  | 2,604,800 |
| 233 | 1.1.2.1.1 | **Proceso de Contratación** | 188d | 2016-08-15 | 2017-05-25 |  | 244d |  |  |  |
| 234 | 1.1.2.1.1.1 | Elaboración Anuncio Expresión de Interés | 10d | 2016-08-15 | 2016-08-26 |  | 244d | 0d | start no earlier than 2016-08-15 |  |
| 235 | 1.1.2.1.1.2 | Solicitud de revisión | 2d | 2016-08-29 | 2016-08-30 | 234 | 524d | 0d |  |  |
| 236 | 1.1.2.1.1.3 | Revisión aprobada | 5d | 2016-08-31 | 2016-09-06 | 235 | 524d | 0d |  |  |
| 237 | 1.1.2.1.1.4 | Publicación anuncio con solicitud de expresiones de interés | 1d | 2016-09-07 | 2016-09-07 | 236 | 524d | 0d |  |  |
| 238 | 1.1.2.1.1.5 | Recepcion de Expresiones de Interes | 11d | 2016-09-08 | 2016-09-22 | 237 | 524d | 0d |  |  |
| 239 | 1.1.2.1.1.6 | Análisis de expresiones de interés | 22d | 2016-09-23 | 2016-10-31 | 238 | 524d | 0d |  |  |
| 240 | 1.1.2.1.1.7 | Elaboración de lista corta | 3d | 2016-11-01 | 2016-11-03 | 239 | 524d | 0d |  |  |
| 241 | 1.1.2.1.1.8 | Solicitud de revisión | 1d | 2016-11-04 | 2016-11-04 | 240 | 524d | 0d |  |  |
| 242 | 1.1.2.1.1.9 | Revisión aprobada | 5d | 2016-11-07 | 2016-11-11 | 241 | 524d | 0d |  |  |
| 243 | 1.1.2.1.1.10 | Elaboración de SP, TdeR y de presupuesto | 10d | 2016-11-14 | 2016-11-25 | 242 | 524d | 0d |  |  |
| 244 | 1.1.2.1.1.11 | Solicitud de revisión | 1d | 2016-11-28 | 2016-11-28 | 243 | 524d | 0d |  |  |
| 245 | 1.1.2.1.1.12 | Revisión aprobada | 5d | 2016-11-29 | 2016-12-05 | 244 | 524d | 0d |  |  |
| 246 | 1.1.2.1.1.13 | Notificación de conformación de lista corta | 5d | 2016-12-06 | 2016-12-12 | 245 | 524d | 0d |  |  |
| 247 | 1.1.2.1.1.14 | Remisión de SP a integrantes de la lista corta | 2d | 2016-12-13 | 2016-12-14 | 246 | 524d | 0d |  |  |
| 248 | 1.1.2.1.1.15 | Presentación de propuesta | 22d | 2016-12-15 | 2017-01-20 | 247 | 524d | 0d |  |  |
| 249 | 1.1.2.1.1.16 | Evaluación de propuestas técnicas | 15d | 2017-01-23 | 2017-02-10 | 248 | 524d | 0d |  |  |
| 250 | 1.1.2.1.1.17 | Solicitud de revisión | 2d | 2017-02-13 | 2017-02-14 | 249 | 524d | 0d |  |  |
| 251 | 1.1.2.1.1.18 | Revisión aprobada | 5d | 2017-02-15 | 2017-02-21 | 250 | 524d | 0d |  |  |
| 252 | 1.1.2.1.1.19 | Notificación de resultados a los participantes (Evaluación técnica) | 2d | 2017-02-22 | 2017-02-23 | 251 | 524d | 0d |  |  |
| 253 | 1.1.2.1.1.20 | Apertura de propuestas de precios | 3d | 2017-02-24 | 2017-02-28 | 252 | 524d | 0d |  |  |
| 254 | 1.1.2.1.1.21 | Evaluación combinada de calidad y costo | 5d | 2017-03-01 | 2017-03-07 | 253 | 524d | 0d |  |  |
| 255 | 1.1.2.1.1.22 | Negociación del contrato | 5d | 2017-03-08 | 2017-03-14 | 254 | 524d | 0d |  |  |
| 256 | 1.1.2.1.1.23 | Solicitud de No Objeción al BID a Evaluación combinada y a borrador del contrato negociado | 2d | 2017-03-15 | 2017-03-16 | 255 | 524d | 0d |  |  |
| 257 | 1.1.2.1.1.24 | No objeción | 5d | 2017-03-17 | 2017-03-23 | 256 | 524d | 0d |  |  |
| 258 | 1.1.2.1.1.25 | Publicación de la adjudicación y notificacion al ganador | 2d | 2017-03-24 | 2017-03-27 | 257 | 524d | 19d |  |  |
| 259 | 1.1.2.1.1.26 | Suscripción del contrato | 3d | 2017-05-02 | 2017-05-04 | 258, 599 | 505d | 0d |  |  |
| 260 | 1.1.2.1.1.27 | Presentación de garantía bancarias | 15d | 2017-05-05 | 2017-05-25 | 259 | 975d |  |  |  |
| 261 | 1.1.2.1.1.28 | Envío de contrato firmado al BID y formulario PRISM | 2d | 2017-05-05 | 2017-05-08 | 259 | 988d |  |  |  |
| 262 | 1.1.2.1.1.29 | Orden de Inicio | 1d | 2017-05-05 | 2017-05-05 | 259, 28SS-18d | 505d | 0d |  |  |
| 263 | 1.1.2.1.2 | Ejecución de la supervisión | 400d | 2017-05-08 | 2018-12-18 | 262 | 589d |  |  |  |

| ID | WBS | Task | Duration | Start | Finish | Predecessors | Total slack | Free slack | Constraint | Cost |
| --- | --- | --- | --- | --- | --- | --- | --- | --- | --- | --- |
| 264 | 1.1.2.1.3 | **Pagos** | 484d | 2017-05-08 | 2019-04-30 |  | 505d |  |  | 2,604,800 |
| 265 | 1.1.2.1.3.1 | Pago No.1 | 4d | 2017-05-08 | 2017-05-11 | 262 | 505d | 0d |  | 118,400 |
| 266 | 1.1.2.1.3.2 | Pago No.2 | 4d | 2017-06-09 | 2017-06-14 | 265FS+20d | 505d | 0d |  | 118,400 |
| 267 | 1.1.2.1.3.3 | Pago No.3 | 4d | 2017-07-13 | 2017-07-18 | 266FS+20d | 505d | 0d |  | 118,400 |
| 268 | 1.1.2.1.3.4 | Pago No.4 | 4d | 2017-08-16 | 2017-08-21 | 267FS+20d | 505d | 0d |  | 118,400 |
| 269 | 1.1.2.1.3.5 | Pago No.5 | 4d | 2017-09-20 | 2017-09-25 | 268FS+20d | 505d | 0d |  | 118,400 |
| 270 | 1.1.2.1.3.6 | Pago No.6 | 4d | 2017-10-31 | 2017-11-03 | 269FS+20d | 505d | 0d |  | 118,400 |
| 271 | 1.1.2.1.3.7 | Pago No.7 | 4d | 2017-12-04 | 2017-12-07 | 270FS+20d | 505d | 0d |  | 118,400 |
| 272 | 1.1.2.1.3.8 | Pago No.8 | 4d | 2018-01-12 | 2018-01-17 | 271FS+20d | 505d | 0d |  | 118,400 |
| 273 | 1.1.2.1.3.9 | Pago No.9 | 4d | 2018-02-15 | 2018-02-20 | 272FS+20d | 793d |  |  | 118,400 |
| 274 | 1.1.2.1.3.10 | Pago No.10 | 4d | 2018-02-15 | 2018-02-20 | 272FS+20d | 505d | 0d |  | 118,400 |
| 275 | 1.1.2.1.3.11 | Pago No.11 | 4d | 2018-03-21 | 2018-04-02 | 274FS+20d | 505d | 0d |  | 118,400 |
| 276 | 1.1.2.1.3.12 | Pago No.12 | 4d | 2018-05-02 | 2018-05-07 | 275FS+20d | 505d | 0d |  | 118,400 |
| 277 | 1.1.2.1.3.13 | Pago No.13 | 4d | 2018-06-05 | 2018-06-08 | 276FS+20d | 505d | 0d |  | 118,400 |
| 278 | 1.1.2.1.3.14 | Pago No.14 | 4d | 2018-07-09 | 2018-07-12 | 277FS+20d | 505d | 0d |  | 118,400 |
| 279 | 1.1.2.1.3.15 | Pago No.15 | 4d | 2018-08-10 | 2018-08-15 | 278FS+20d | 505d | 0d |  | 118,400 |
| 280 | 1.1.2.1.3.16 | Pago No.16 | 4d | 2018-09-13 | 2018-09-18 | 279FS+20d | 505d | 0d |  | 118,400 |
| 281 | 1.1.2.1.3.17 | Pago No.17 | 4d | 2018-10-24 | 2018-10-29 | 280FS+20d | 505d | 0d |  | 118,400 |
| 282 | 1.1.2.1.3.18 | Pago No.18 | 4d | 2018-11-27 | 2018-11-30 | 281FS+20d | 505d | 0d |  | 118,400 |
| 283 | 1.1.2.1.3.19 | Pago No.19 | 4d | 2019-01-08 | 2019-01-11 | 282FS+20d | 505d | 0d |  | 118,400 |
| 284 | 1.1.2.1.3.20 | Pago No. 20 | 4d | 2019-02-11 | 2019-02-14 | 283FS+20d | 505d | 0d |  | 118,400 |
| 285 | 1.1.2.1.3.21 | Pago No. 21 | 4d | 2019-03-15 | 2019-03-20 | 284FS+20d | 505d | 0d |  | 118,400 |
| 286 | 1.1.2.1.3.22 | Pago No. 22 | 4d | 2019-04-25 | 2019-04-30 | 285FS+20d | 505d |  |  | 118,400 |
| 287 | 1.1.2.2 | **Supervisión Construcción de obras Corredor Turístico Libramiento El Progreso (siempre que cumpla con los criterios de elegibilidad)** | 626d | 2018-01-08 | 2020-07-28 |  | 59d |  |  | 1,470,200 |
| 288 | 1.1.2.2.1 | **Proceso de Contratación** | 186d | 2018-01-08 | 2018-10-09 |  | 59d |  |  |  |
| 289 | 1.1.2.2.1.1 | Elaboración Anuncio Expresión de Interés | 10d | 2018-01-08 | 2018-01-19 |  | 59d | 0d | start no earlier than 2018-01-08 |  |
| 290 | 1.1.2.2.1.2 | Solicitud de no objeción del BID | 2d | 2018-01-22 | 2018-01-23 | 289 | 59d | 0d |  |  |
| 291 | 1.1.2.2.1.3 | No objeción del BID | 5d | 2018-01-24 | 2018-01-30 | 290 | 59d | 0d |  |  |
| 292 | 1.1.2.2.1.4 | Publicación anuncio con solicitud de expresiones de interés | 1d | 2018-01-31 | 2018-01-31 | 291 | 59d | 0d |  |  |
| 293 | 1.1.2.2.1.5 | Recepcion de Expresiones de Interes | 11d | 2018-02-01 | 2018-02-15 | 292 | 59d | 0d |  |  |
| 294 | 1.1.2.2.1.6 | Análisis de expresiones de interés | 22d | 2018-02-16 | 2018-03-19 | 293 | 59d | 0d |  |  |
| 295 | 1.1.2.2.1.7 | Elaboración de lista corta | 3d | 2018-03-20 | 2018-03-22 | 294 | 59d | 0d |  |  |
| 296 | 1.1.2.2.1.8 | Solicitud de no objeción al BID de lista corta | 1d | 2018-03-23 | 2018-03-23 | 295 | 59d | 0d |  |  |
| 297 | 1.1.2.2.1.9 | No objeción del BID a la lista corta | 5d | 2018-04-02 | 2018-04-06 | 296 | 59d | 0d |  |  |
| 298 | 1.1.2.2.1.10 | Elaboración de SP, TdeR y de presupuesto | 10d | 2018-04-09 | 2018-04-20 | 297 | 59d | 0d |  |  |
| 299 | 1.1.2.2.1.11 | Solicitud de no objeción al BID SP y Presupuesto | 1d | 2018-04-23 | 2018-04-23 | 298 | 59d | 0d |  |  |
| 300 | 1.1.2.2.1.12 | No objeción del BID al SP y presupuesto | 5d | 2018-04-24 | 2018-04-30 | 299 | 59d | 0d |  |  |
| 301 | 1.1.2.2.1.13 | Notificación de conformación de lista corta | 5d | 2018-05-02 | 2018-05-08 | 300 | 59d | 0d |  |  |
| 302 | 1.1.2.2.1.14 | Remisión de SP a integrantes de la lista corta | 2d | 2018-05-09 | 2018-05-10 | 301 | 59d | 0d |  |  |
| 303 | 1.1.2.2.1.15 | Presentación de propuesta | 22d | 2018-05-11 | 2018-06-11 | 302 | 59d | 0d |  |  |
| 304 | 1.1.2.2.1.16 | Evaluación de propuestas técnicas | 22d | 2018-06-12 | 2018-07-11 | 303 | 59d | 0d |  |  |
| 305 | 1.1.2.2.1.17 | Solicitud de no objeción del BID | 2d | 2018-07-12 | 2018-07-13 | 304 | 59d | 0d |  |  |
| 306 | 1.1.2.2.1.18 | No objeción del BID | 5d | 2018-07-16 | 2018-07-20 | 305 | 59d | 0d |  |  |
| 307 | 1.1.2.2.1.19 | Notificación de resultados a los participantes (Evaluación técnica) | 2d | 2018-07-23 | 2018-07-24 | 306 | 59d | 0d |  |  |
| 308 | 1.1.2.2.1.20 | Apertura de propuestas de precios | 3d | 2018-07-25 | 2018-07-27 | 307 | 59d | 0d |  |  |
| 309 | 1.1.2.2.1.21 | Evaluación combinada de calidad y costo | 5d | 2018-07-30 | 2018-08-03 | 308 | 59d | 0d |  |  |
| 310 | 1.1.2.2.1.22 | Negociación del contrato | 10d | 2018-08-06 | 2018-08-17 | 309 | 59d | 0d |  |  |
| 311 | 1.1.2.2.1.23 | Solicitud de No Objeción al BID a Evaluación combinada y a borrador del contrato negociado | 5d | 2018-08-20 | 2018-08-24 | 310 | 59d | 0d |  |  |
| 312 | 1.1.2.2.1.24 | No objeción | 5d | 2018-08-27 | 2018-08-31 | 311 | 59d | 0d |  |  |
| 313 | 1.1.2.2.1.25 | Publicación de la adjudicación y notificacion al ganador | 2d | 2018-09-03 | 2018-09-04 | 312 | 59d | 0d |  |  |
| 314 | 1.1.2.2.1.26 | Suscripción del contrato | 5d | 2018-09-05 | 2018-09-11 | 313 | 59d | 0d |  |  |
| 315 | 1.1.2.2.1.27 | Presentación de garantía bancarias | 15d | 2018-09-12 | 2018-10-09 | 314 | 639d |  |  |  |
| 316 | 1.1.2.2.1.28 | Envío de contrato firmado al BID y formulario PRISM | 2d | 2018-09-12 | 2018-09-13 | 314 | 652d |  |  |  |
| 317 | 1.1.2.2.1.29 | Orden de Inicio | 1d | 2018-10-09 | 2018-10-09 | 314, 160 | 45d | 0d |  |  |
| 318 | 1.1.2.2.2 | Ejecución de la supervisión | 410d | 2018-10-10 | 2020-06-16 | 317 | 229d |  |  |  |

| ID | WBS | Task | Duration | Start | Finish | Predecessors | Total slack | Free slack | Constraint | Cost |
| --- | --- | --- | --- | --- | --- | --- | --- | --- | --- | --- |
| 319 | 1.1.2.2.3 | **Pagos** | 420d | 2018-11-07 | 2020-07-28 |  | 199d |  |  | 1,470,200 |
| 320 | 1.1.2.2.3.1 | Pago No.1 | 2d | 2018-11-07 | 2018-11-08 | 317FS+20d | 199d | 0d |  | 73,510 |
| 321 | 1.1.2.2.3.2 | Pago No.2 | 2d | 2018-12-07 | 2018-12-10 | 320FS+20d | 199d | 0d |  | 73,510 |
| 322 | 1.1.2.2.3.3 | Pago No.3 | 2d | 2019-01-16 | 2019-01-17 | 321FS+20d | 199d | 0d |  | 73,510 |
| 323 | 1.1.2.2.3.4 | Pago No.4 | 2d | 2019-02-15 | 2019-02-18 | 322FS+20d | 199d | 0d |  | 73,510 |
| 324 | 1.1.2.2.3.5 | Pago No.5 | 2d | 2019-03-19 | 2019-03-20 | 323FS+20d | 199d | 0d |  | 73,510 |
| 325 | 1.1.2.2.3.6 | Pago No.6 | 2d | 2019-04-25 | 2019-04-26 | 324FS+20d | 199d | 0d |  | 73,510 |
| 326 | 1.1.2.2.3.7 | Pago No.7 | 2d | 2019-05-28 | 2019-05-29 | 325FS+20d | 199d | 0d |  | 73,510 |
| 327 | 1.1.2.2.3.8 | Pago No.8 | 2d | 2019-06-27 | 2019-06-28 | 326FS+20d | 199d | 0d |  | 73,510 |
| 328 | 1.1.2.2.3.9 | Pago No.9 | 2d | 2019-07-29 | 2019-07-30 | 327FS+20d | 199d | 0d |  | 73,510 |
| 329 | 1.1.2.2.3.10 | Pago No.10 | 2d | 2019-08-28 | 2019-08-29 | 328FS+20d | 199d | 0d |  | 73,510 |
| 330 | 1.1.2.2.3.11 | Pago No.11 | 2d | 2019-09-27 | 2019-09-30 | 329FS+20d | 199d | 0d |  | 73,510 |
| 331 | 1.1.2.2.3.12 | Pago No.12 | 2d | 2019-11-04 | 2019-11-05 | 330FS+20d | 199d | 0d |  | 73,510 |
| 332 | 1.1.2.2.3.13 | Pago No.13 | 2d | 2019-12-04 | 2019-12-05 | 331FS+20d | 199d | 0d |  | 73,510 |
| 333 | 1.1.2.2.3.14 | Pago No.14 | 2d | 2020-01-14 | 2020-01-15 | 332FS+20d | 199d | 0d |  | 73,510 |
| 334 | 1.1.2.2.3.15 | Pago No.15 | 2d | 2020-02-13 | 2020-02-14 | 333FS+20d | 199d | 0d |  | 73,510 |
| 335 | 1.1.2.2.3.16 | Pago No.16 | 2d | 2020-03-16 | 2020-03-17 | 334FS+20d | 199d | 0d |  | 73,510 |
| 336 | 1.1.2.2.3.17 | Pago No.17 | 2d | 2020-04-23 | 2020-04-24 | 335FS+20d | 199d | 0d |  | 73,510 |
| 337 | 1.1.2.2.3.18 | Pago No.18 | 2d | 2020-05-26 | 2020-05-27 | 336FS+20d | 199d | 0d |  | 73,510 |
| 338 | 1.1.2.2.3.19 | Pago No.19 | 2d | 2020-06-25 | 2020-06-26 | 337FS+20d | 199d | 0d |  | 73,510 |
| 339 | 1.1.2.2.3.20 | Pago No.20 | 2d | 2020-07-27 | 2020-07-28 | 338FS+20d | 199d |  |  | 73,510 |
| 340 | 1.1.3 | **Estudios Técnicos** | 321d | 2018-02-05 | 2019-05-30 |  | 484d |  |  | 500,000 |
| 341 | 1.1.3.1 | **Estudios Técnicos, Económicos y Socioambientales** | 321d | 2018-02-05 | 2019-05-30 |  | 484d |  |  | 500,000 |
| 342 | 1.1.3.1.1 | **Proceso de Contratación** | 152d | 2018-02-05 | 2018-09-12 |  | 484d |  |  |  |
| 343 | 1.1.3.1.1.1 | Elaboración Anuncio | 3d | 2018-02-05 | 2018-02-07 |  | 484d | 0d | start no earlier than 2018-02-05 |  |
| 344 | 1.1.3.1.1.2 | Solicitud de no objeción del BID | 1d | 2018-02-08 | 2018-02-08 | 343 | 484d | 0d |  |  |
| 345 | 1.1.3.1.1.3 | No objeción del BID | 5d | 2018-02-09 | 2018-02-15 | 344 | 484d | 0d |  |  |
| 346 | 1.1.3.1.1.4 | Publicación anuncio con solicitud de expresiones de interés | 2d | 2018-02-16 | 2018-02-19 | 345 | 484d | 0d |  |  |
| 347 | 1.1.3.1.1.5 | Recepcion de Expresiones de Interes | 11d | 2018-02-20 | 2018-03-06 | 346 | 484d | 0d |  |  |
| 348 | 1.1.3.1.1.6 | Análisis de expresiones de interés | 10d | 2018-03-07 | 2018-03-20 | 347 | 484d | 0d |  |  |
| 349 | 1.1.3.1.1.7 | Elaboración de lista corta | 2d | 2018-03-21 | 2018-03-22 | 348 | 484d | 0d |  |  |
| 350 | 1.1.3.1.1.8 | Elaboración de SP, TdeR y de presupuesto | 20d | 2018-03-23 | 2018-04-26 | 349 | 484d | 0d |  |  |
| 351 | 1.1.3.1.1.9 | Solicitud de no objeción al BID de SP, Presupuesto y lista corta | 1d | 2018-04-27 | 2018-04-27 | 350 | 484d | 0d |  |  |
| 352 | 1.1.3.1.1.10 | No objeción del BID de SP, Presupuesto y lista corta | 5d | 2018-04-30 | 2018-05-07 | 351 | 484d | 0d |  |  |
| 353 | 1.1.3.1.1.11 | Notificación de conformación de lista corta | 2d | 2018-05-08 | 2018-05-09 | 352 | 484d | 0d |  |  |
| 354 | 1.1.3.1.1.12 | Remisión de SP a integrantes de la lista corta | 2d | 2018-05-10 | 2018-05-11 | 353 | 484d | 0d |  |  |
| 355 | 1.1.3.1.1.13 | Presentación de propuesta | 22d | 2018-05-14 | 2018-06-12 | 354 | 484d | 0d |  |  |
| 356 | 1.1.3.1.1.14 | Evaluación de propuestas técnicas | 15d | 2018-06-13 | 2018-07-03 | 355 | 484d | 0d |  |  |
| 357 | 1.1.3.1.1.15 | Solicitud de no objeción del BID | 2d | 2018-07-04 | 2018-07-05 | 356 | 484d | 0d |  |  |
| 358 | 1.1.3.1.1.16 | No objeción del BID | 5d | 2018-07-06 | 2018-07-12 | 357 | 484d | 0d |  |  |
| 359 | 1.1.3.1.1.17 | Notificación de resultados a los participantes (Evaluación técnica) | 2d | 2018-07-13 | 2018-07-16 | 358 | 484d | 0d |  |  |
| 360 | 1.1.3.1.1.18 | Apertura de propuestas de precios | 3d | 2018-07-17 | 2018-07-19 | 359 | 484d | 0d |  |  |
| 361 | 1.1.3.1.1.19 | Evaluación combinada de calidad y costo | 5d | 2018-07-20 | 2018-07-26 | 360 | 484d | 0d |  |  |
| 362 | 1.1.3.1.1.20 | Negociación del contrato | 5d | 2018-07-27 | 2018-08-02 | 361 | 484d | 0d |  |  |
| 363 | 1.1.3.1.1.21 | Solicitud de No Objeción al BID a Evaluación combinada y a borrador del contrato negociado | 2d | 2018-08-03 | 2018-08-06 | 362 | 484d | 0d |  |  |
| 364 | 1.1.3.1.1.22 | No objeción | 5d | 2018-08-07 | 2018-08-13 | 363 | 484d | 0d |  |  |
| 365 | 1.1.3.1.1.23 | Aprobacion del Contrato por el Consejo Directivo | 15d | 2018-08-14 | 2018-09-03 | 364 | 484d | 0d |  |  |
| 366 | 1.1.3.1.1.24 | Publicación de la adjudicación y notificacion al ganador | 2d | 2018-09-04 | 2018-09-05 | 365 | 484d | 0d |  |  |
| 367 | 1.1.3.1.1.25 | Suscripción del contrato | 3d | 2018-09-06 | 2018-09-10 | 366 | 484d | 0d |  |  |
| 368 | 1.1.3.1.1.26 | Envío de contrato firmado al BID y formulario PRISM | 2d | 2018-09-11 | 2018-09-12 | 367 | 653d |  |  |  |
| 369 | 1.1.3.1.1.27 | Orden de Inicio | 1d | 2018-09-11 | 2018-09-11 | 367 | 484d | 0d |  |  |
| 370 | 1.1.3.1.2 | Ejecución del diseño | 132d | 2018-09-12 | 2019-03-29 | 369 | 522d |  |  |  |

| ID | WBS | Task | Duration | Start | Finish | Predecessors | Total slack | Free slack | Cost |
| --- | --- | --- | --- | --- | --- | --- | --- | --- | --- |
| 371 | 1.1.3.1.3 | **Pagos** | 170d | 2018-09-12 | 2019-05-30 |  | 484d |  | 500,000 |
| 372 | 1.1.3.1.3.1 | Pago 1 | 2d | 2018-09-12 | 2018-09-13 | 369 | 484d | 0d | 100,000 |
| 373 | 1.1.3.1.3.2 | pago 2 | 2d | 2018-11-16 | 2018-11-19 | 372FS+40d | 484d | 0d | 100,000 |
| 374 | 1.1.3.1.3.3 | Pago 3 | 2d | 2019-01-23 | 2019-01-24 | 373FS+40d | 484d | 0d | 100,000 |
| 375 | 1.1.3.1.3.4 | Pago 4 | 2d | 2019-03-22 | 2019-03-25 | 374FS+40d | 484d | 0d | 100,000 |
| 376 | 1.1.3.1.3.5 | Pago 5 | 2d | 2019-05-29 | 2019-05-30 | 375FS+40d | 484d |  | 100,000 |
| 377 | 1.1.4 | **Enfoque de Género** | 577d | 2017-02-28 | 2019-07-10 |  | 455d |  | 250,000 |
| 378 | 1.1.4.1 | **Proveedores de Servicios Tramo muestra** | 221d | 2017-02-28 | 2018-01-25 |  | 621d |  | 100,000 |
| 379 | 1.1.4.1.1 | **Proceso de contratación (LPN)** | 87d | 2017-02-28 | 2017-07-06 |  | 621d | 0d |  |
| 380 | 1.1.4.1.1.1 | Elaboración especificaciones técnicas | 20d | 2017-02-28 | 2017-03-27 | 30SS-60d | 621d | 0d |  |
| 381 | 1.1.4.1.1.2 | Elaboración documento de licitación | 10d | 2017-03-28 | 2017-04-17 | 380 | 621d | 0d |  |
| 382 | 1.1.4.1.1.3 | Solicitud de No Objeción | 2d | 2017-04-18 | 2017-04-19 | 381 | 621d | 0d |  |
| 383 | 1.1.4.1.1.4 | No Objeción | 5d | 2017-04-20 | 2017-04-26 | 382 | 621d | 0d |  |
| 384 | 1.1.4.1.1.5 | Publicación / Invitación Proceso | 1d | 2017-04-27 | 2017-04-27 | 383 | 621d | 0d |  |
| 385 | 1.1.4.1.1.6 | Presentación de ofertas | 22d | 2017-04-28 | 2017-05-30 | 384 | 621d | 0d |  |
| 386 | 1.1.4.1.1.7 | Evaluación y calificación de ofertas | 15d | 2017-05-31 | 2017-06-20 | 385 | 621d | 0d |  |
| 387 | 1.1.4.1.1.8 | Solicitud de no objeción del BID | 2d | 2017-06-21 | 2017-06-22 | 386 | 621d | 0d |  |
| 388 | 1.1.4.1.1.9 | No objeción del BID | 5d | 2017-06-23 | 2017-06-29 | 387 | 621d | 0d |  |
| 389 | 1.1.4.1.1.10 | Suscripción de Contrato | 5d | 2017-06-30 | 2017-07-06 | 388 | 621d | 0d |  |
| 390 | 1.1.4.1.2 | Ejecución | 132d | 2017-07-07 | 2018-01-23 | 389 | 811d | 0d |  |
| 391 | 1.1.4.1.3 | **Pagos** | 124d | 2017-07-21 | 2018-01-25 |  | 811d |  | 100,000 |
| 392 | 1.1.4.1.3.1 | Pago 1 | 2d | 2017-07-21 | 2017-07-24 | 389FS+10d | 871d | 0d | 20,000 |
| 393 | 1.1.4.1.3.2 | Pago 2 | 2d | 2017-10-25 | 2017-10-26 | 392FS+60d | 871d |  | 40,000 |
| 394 | 1.1.4.1.3.3 | Pago 3 | 2d | 2018-01-24 | 2018-01-25 | 390 | 811d |  | 40,000 |

| ID | WBS | Task | Duration | Start | Finish | Predecessors | Total slack | Free slack | Cost |
| --- | --- | --- | --- | --- | --- | --- | --- | --- | --- |
| 395 | 1.1.4.2 | **Proveedores de Servicios Tramo por definir** | 221d | 2018-08-13 | 2019-07-10 |  | 455d |  | 100,000 |
| 396 | 1.1.4.2.1 | **Proceso de contratación (LPN)** | 87d | 2018-08-13 | 2018-12-18 |  | 455d |  |  |
| 397 | 1.1.4.2.1.1 | Elaboración especificaciones técnicas | 20d | 2018-08-13 | 2018-09-07 | 89SS-60d | 455d | 0d |  |
| 398 | 1.1.4.2.1.2 | Elaboración documento de licitación | 10d | 2018-09-10 | 2018-09-21 | 397 | 455d | 0d |  |
| 399 | 1.1.4.2.1.3 | Solicitud de No Objeción | 2d | 2018-09-24 | 2018-09-25 | 398 | 455d | 0d |  |
| 400 | 1.1.4.2.1.4 | No Objeción | 5d | 2018-09-26 | 2018-10-09 | 399 | 455d | 0d |  |
| 401 | 1.1.4.2.1.5 | Publicación / Invitación Proceso | 1d | 2018-10-10 | 2018-10-10 | 400 | 455d | 0d |  |
| 402 | 1.1.4.2.1.6 | Presentación de ofertas | 22d | 2018-10-11 | 2018-11-09 | 401 | 455d | 0d |  |
| 403 | 1.1.4.2.1.7 | Evaluación y calificación de ofertas | 15d | 2018-11-12 | 2018-11-30 | 402 | 455d | 0d |  |
| 404 | 1.1.4.2.1.8 | Solicitud de no objeción del BID | 2d | 2018-12-03 | 2018-12-04 | 403 | 455d | 0d |  |
| 405 | 1.1.4.2.1.9 | No objeción del BID | 5d | 2018-12-05 | 2018-12-11 | 404 | 455d | 0d |  |
| 406 | 1.1.4.2.1.10 | Suscripción de Contrato | 5d | 2018-12-12 | 2018-12-18 | 405 | 455d | 0d |  |
| 407 | 1.1.4.2.2 | Ejecución | 132d | 2018-12-19 | 2019-07-08 | 406 | 455d | 0d |  |
| 408 | 1.1.4.2.3 | **Pagos** | 124d | 2019-01-10 | 2019-07-10 |  | 455d |  | 100,000 |
| 409 | 1.1.4.2.3.1 | Pago 1 | 2d | 2019-01-10 | 2019-01-11 | 406FS+10d | 515d | 0d | 20,000 |
| 410 | 1.1.4.2.3.2 | Pago 2 | 2d | 2019-04-08 | 2019-04-09 | 409FS+60d | 515d |  | 40,000 |
| 411 | 1.1.4.2.3.3 | Pago 3 | 2d | 2019-07-09 | 2019-07-10 | 407 | 455d |  | 40,000 |
| 412 | 1.1.4.3 | **Asistencia Técnica** | 440d | 2017-09-18 | 2019-07-10 |  | 455d |  | 50,000 |
| 413 | 1.1.4.3.1 | **Proceso de contratación** | 44d | 2017-09-18 | 2017-11-23 |  | 621d |  |  |
| 414 | 1.1.4.3.1.1 | Elaboración de TDRs y de presupuesto | 3d | 2017-09-18 | 2017-09-20 | 379FS+50d | 621d | 0d |  |
| 415 | 1.1.4.3.1.2 | Solicitud de No Objeción | 2d | 2017-09-21 | 2017-09-22 | 414 | 621d | 0d |  |
| 416 | 1.1.4.3.1.3 | No Objeción a TdeR | 15d | 2017-09-25 | 2017-10-20 | 415 | 621d | 0d |  |
| 417 | 1.1.4.3.1.4 | Publicación / Invitación Proceso | 1d | 2017-10-23 | 2017-10-23 | 416 | 621d | 0d |  |
| 418 | 1.1.4.3.1.5 | Presentación de hojas de vida | 5d | 2017-10-24 | 2017-10-30 | 417 | 621d | 0d |  |
| 419 | 1.1.4.3.1.6 | Evaluación y calificación de hojas de vida | 5d | 2017-10-31 | 2017-11-06 | 418 | 621d | 0d |  |
| 420 | 1.1.4.3.1.7 | Solicitud de no objeción del BID | 2d | 2017-11-07 | 2017-11-08 | 419 | 621d | 0d |  |
| 421 | 1.1.4.3.1.8 | No objeción del BID | 5d | 2017-11-09 | 2017-11-15 | 420 | 621d | 0d |  |
| 422 | 1.1.4.3.1.9 | Negociación del contrato | 1d | 2017-11-16 | 2017-11-16 | 421 | 621d | 0d |  |
| 423 | 1.1.4.3.1.10 | Suscripción de Contrato | 5d | 2017-11-17 | 2017-11-23 | 422 | 621d | 0d |  |
| 424 | 1.1.4.3.2 | Ejecucion | 230d | 2017-11-24 | 2018-11-02 | 423 | 621d |  |  |

| ID | WBS | Task | Duration | Start | Finish | Predecessors | Total slack | Free slack | Cost |
| --- | --- | --- | --- | --- | --- | --- | --- | --- | --- |
| 425 | 1.1.4.3.3 | **Pagos** | 358d | 2018-01-24 | 2019-07-10 |  | 455d |  | 50,000 |
| 426 | 1.1.4.3.3.1 | Pago 1 | 2d | 2018-01-24 | 2018-01-25 | 390 | 811d |  | 25,000 |
| 427 | 1.1.4.3.3.2 | Pago 2 | 2d | 2019-07-09 | 2019-07-10 | 407 | 455d |  | 25,000 |
| 428 | 1.2 | **COMPONENTE 2: FORTALECIMIENTO INSTITUCIONAL INSEP** | 333d | 2017-05-30 | 2018-10-08 |  | 640d |  | 750,000 |
| 429 | 1.2.1 | **Capacitación de recursos humanos** | 149d | 2017-05-30 | 2018-01-08 |  | 824d |  | 330,000 |
| 430 | 1.2.1.1 | **Proceso de Contratación LPN** | 87d | 2017-05-30 | 2017-09-28 |  | 824d |  |  |
| 431 | 1.2.1.1.1 | Elaboración especificaciones técnicas | 20d | 2017-05-30 | 2017-06-26 | 599FS+20d | 824d | 0d |  |
| 432 | 1.2.1.1.2 | Elaboración documento de licitación | 10d | 2017-06-27 | 2017-07-10 | 431 | 824d | 0d |  |
| 433 | 1.2.1.1.3 | Solicitud de No Objeción | 2d | 2017-07-11 | 2017-07-12 | 432 | 824d | 0d |  |
| 434 | 1.2.1.1.4 | No Objeción | 5d | 2017-07-13 | 2017-07-19 | 433 | 824d | 0d |  |
| 435 | 1.2.1.1.5 | Publicación / Invitación Proceso | 1d | 2017-07-20 | 2017-07-20 | 434 | 824d | 0d |  |
| 436 | 1.2.1.1.6 | Presentación de ofertas | 22d | 2017-07-21 | 2017-08-21 | 435 | 824d | 0d |  |
| 437 | 1.2.1.1.7 | Evaluación y calificación de ofertas | 15d | 2017-08-22 | 2017-09-11 | 436 | 824d | 0d |  |
| 438 | 1.2.1.1.8 | Solicitud de no objeción del BID | 2d | 2017-09-12 | 2017-09-13 | 437 | 824d | 0d |  |
| 439 | 1.2.1.1.9 | No objeción del BID | 5d | 2017-09-14 | 2017-09-21 | 438 | 824d | 0d |  |
| 440 | 1.2.1.1.10 | Suscripción de Contrato | 5d | 2017-09-22 | 2017-09-28 | 439 | 824d | 0d |  |
| 441 | 1.2.1.2 | Ejecución de contrato | 44d | 2017-09-29 | 2017-12-06 | 440 | 824d | 0d |  |
| 442 | 1.2.1.3 | Pagos | 2d | 2018-01-05 | 2018-01-08 | 441SS+60d | 824d |  | 330,000 |
| 443 | 1.2.2 | **Adquisición de equipo informático** | 133d | 2017-09-05 | 2018-03-23 |  | 770d |  | 50,000 |
| 444 | 1.2.2.1 | **Proceso de Contratación LPN** | 87d | 2017-09-05 | 2018-01-18 |  | 770d |  |  |
| 445 | 1.2.2.1.1 | Elaboración especificaciones técnicas | 20d | 2017-09-05 | 2017-10-10 | 599FS+90d | 770d | 0d |  |
| 446 | 1.2.2.1.2 | Elaboración documento de licitación | 10d | 2017-10-11 | 2017-10-24 | 445 | 770d | 0d |  |
| 447 | 1.2.2.1.3 | Solicitud de No Objeción | 2d | 2017-10-25 | 2017-10-26 | 446 | 770d | 0d |  |
| 448 | 1.2.2.1.4 | No Objeción | 5d | 2017-10-27 | 2017-11-02 | 447 | 770d | 0d |  |
| 449 | 1.2.2.1.5 | Publicación / Invitación Proceso | 1d | 2017-11-03 | 2017-11-03 | 448 | 770d | 0d |  |
| 450 | 1.2.2.1.6 | Presentación de ofertas | 22d | 2017-11-06 | 2017-12-05 | 449 | 770d | 0d |  |
| 451 | 1.2.2.1.7 | Evaluación y calificación de ofertas | 15d | 2017-12-06 | 2018-01-02 | 450 | 770d | 0d |  |
| 452 | 1.2.2.1.8 | Solicitud de no objeción del BID | 2d | 2018-01-03 | 2018-01-04 | 451 | 770d | 0d |  |
| 453 | 1.2.2.1.9 | No objeción del BID | 5d | 2018-01-05 | 2018-01-11 | 452 | 770d | 0d |  |
| 454 | 1.2.2.1.10 | Suscripción de Contrato | 5d | 2018-01-12 | 2018-01-18 | 453 | 770d | 0d |  |
| 455 | 1.2.2.2 | Ejecución de contrato | 44d | 2018-01-19 | 2018-03-21 | 454 | 770d | 0d |  |
| 456 | 1.2.2.3 | Pagos | 2d | 2018-03-22 | 2018-03-23 | 455 | 770d |  | 50,000 |

| ID | WBS | Task | Duration | Start | Finish | Predecessors | Total slack | Free slack | Cost |
| --- | --- | --- | --- | --- | --- | --- | --- | --- | --- |
| 457 | 1.2.3 | **Adquisición de software** | 133d | 2018-03-21 | 2018-10-08 |  | 640d |  | 70,000 |
| 458 | 1.2.3.1 | **Proceso de Contratación LPN** | 87d | 2018-03-21 | 2018-07-27 |  | 640d |  |  |
| 459 | 1.2.3.1.1 | Elaboración especificaciones técnicas | 20d | 2018-03-21 | 2018-04-24 | 599FS+220d | 640d | 0d |  |
| 460 | 1.2.3.1.2 | Elaboración documento de licitación | 10d | 2018-04-25 | 2018-05-09 | 459 | 640d | 0d |  |
| 461 | 1.2.3.1.3 | Solicitud de No Objeción | 2d | 2018-05-10 | 2018-05-11 | 460 | 640d | 0d |  |
| 462 | 1.2.3.1.4 | No Objeción | 5d | 2018-05-14 | 2018-05-18 | 461 | 640d | 0d |  |
| 463 | 1.2.3.1.5 | Publicación / Invitación Proceso | 1d | 2018-05-21 | 2018-05-21 | 462 | 640d | 0d |  |
| 464 | 1.2.3.1.6 | Presentación de ofertas | 22d | 2018-05-22 | 2018-06-20 | 463 | 640d | 0d |  |
| 465 | 1.2.3.1.7 | Evaluación y calificación de ofertas | 15d | 2018-06-21 | 2018-07-11 | 464 | 640d | 0d |  |
| 466 | 1.2.3.1.8 | Solicitud de no objeción del BID | 2d | 2018-07-12 | 2018-07-13 | 465 | 640d | 0d |  |
| 467 | 1.2.3.1.9 | No objeción del BID | 5d | 2018-07-16 | 2018-07-20 | 466 | 640d | 0d |  |
| 468 | 1.2.3.1.10 | Suscripción de Contrato | 5d | 2018-07-23 | 2018-07-27 | 467 | 640d | 0d |  |
| 469 | 1.2.3.2 | Ejecución de contrato | 44d | 2018-07-30 | 2018-09-27 | 468 | 640d | 0d |  |
| 470 | 1.2.3.3 | Pagos | 2d | 2018-09-28 | 2018-10-08 | 469 | 640d |  | 70,000 |
| 471 | 1.2.4 | **Acondicionamiento de espacios de oficinas** | 133d | 2018-03-21 | 2018-10-08 |  | 640d |  | 200,000 |
| 472 | 1.2.4.1 | **Proceso de Contratación LPN** | 87d | 2018-03-21 | 2018-07-27 |  | 640d |  |  |
| 473 | 1.2.4.1.1 | Elaboración especificaciones técnicas | 20d | 2018-03-21 | 2018-04-24 | 599FS+220d | 640d | 0d |  |
| 474 | 1.2.4.1.2 | Elaboración documento de licitación | 10d | 2018-04-25 | 2018-05-09 | 473 | 640d | 0d |  |
| 475 | 1.2.4.1.3 | Solicitud de No Objeción | 2d | 2018-05-10 | 2018-05-11 | 474 | 640d | 0d |  |
| 476 | 1.2.4.1.4 | No Objeción | 5d | 2018-05-14 | 2018-05-18 | 475 | 640d | 0d |  |
| 477 | 1.2.4.1.5 | Publicación / Invitación Proceso | 1d | 2018-05-21 | 2018-05-21 | 476 | 640d | 0d |  |
| 478 | 1.2.4.1.6 | Presentación de ofertas | 22d | 2018-05-22 | 2018-06-20 | 477 | 640d | 0d |  |
| 479 | 1.2.4.1.7 | Evaluación y calificación de ofertas | 15d | 2018-06-21 | 2018-07-11 | 478 | 640d | 0d |  |
| 480 | 1.2.4.1.8 | Solicitud de no objeción del BID | 2d | 2018-07-12 | 2018-07-13 | 479 | 640d | 0d |  |
| 481 | 1.2.4.1.9 | No objeción del BID | 5d | 2018-07-16 | 2018-07-20 | 480 | 640d | 0d |  |
| 482 | 1.2.4.1.10 | Suscripción de Contrato | 5d | 2018-07-23 | 2018-07-27 | 481 | 640d | 0d |  |
| 483 | 1.2.4.2 | Ejecución de contrato | 44d | 2018-07-30 | 2018-09-27 | 482 | 640d | 0d |  |
| 484 | 1.2.4.3 | Pagos | 2d | 2018-09-28 | 2018-10-08 | 483 | 640d |  | 200,000 |

| ID | WBS | Task | Duration | Start | Finish | Predecessors | Total slack | Free slack | Cost |
| --- | --- | --- | --- | --- | --- | --- | --- | --- | --- |
| 485 | 1.2.5 | **Equipos de Transporte** | 133d | 2018-03-21 | 2018-10-08 |  | 640d |  | 100,000 |
| 486 | 1.2.5.1 | **Proceso de Contratación LPN** | 87d | 2018-03-21 | 2018-07-27 |  | 640d |  |  |
| 487 | 1.2.5.1.1 | Elaboración especificaciones técnicas | 20d | 2018-03-21 | 2018-04-24 | 599FS+220d | 640d | 0d |  |
| 488 | 1.2.5.1.2 | Elaboración documento de licitación | 10d | 2018-04-25 | 2018-05-09 | 487 | 640d | 0d |  |
| 489 | 1.2.5.1.3 | Solicitud de No Objeción | 2d | 2018-05-10 | 2018-05-11 | 488 | 640d | 0d |  |
| 490 | 1.2.5.1.4 | No Objeción | 5d | 2018-05-14 | 2018-05-18 | 489 | 640d | 0d |  |
| 491 | 1.2.5.1.5 | Publicación / Invitación Proceso | 1d | 2018-05-21 | 2018-05-21 | 490 | 640d | 0d |  |
| 492 | 1.2.5.1.6 | Presentación de ofertas | 22d | 2018-05-22 | 2018-06-20 | 491 | 640d | 0d |  |
| 493 | 1.2.5.1.7 | Evaluación y calificación de ofertas | 15d | 2018-06-21 | 2018-07-11 | 492 | 640d | 0d |  |
| 494 | 1.2.5.1.8 | Solicitud de no objeción del BID | 2d | 2018-07-12 | 2018-07-13 | 493 | 640d | 0d |  |
| 495 | 1.2.5.1.9 | No objeción del BID | 5d | 2018-07-16 | 2018-07-20 | 494 | 640d | 0d |  |
| 496 | 1.2.5.1.10 | Suscripción de Contrato | 5d | 2018-07-23 | 2018-07-27 | 495 | 640d | 0d |  |
| 497 | 1.2.5.2 | Ejecución de contrato | 44d | 2018-07-30 | 2018-09-27 | 496 | 640d | 0d |  |
| 498 | 1.2.5.3 | Pagos | 2d | 2018-09-28 | 2018-10-08 | 497 | 640d |  | 100,000 |
| 499 | 1.3 | **OTROS GASTOS** | 917d | 2017-08-16 | 2021-05-19 |  | 0d |  | 1,000,000 |
| 500 | 1.3.1 | **Gestión del Programa** | 917d | 2017-08-16 | 2021-05-19 |  | 0d |  | 1,000,000 |
| 501 | 1.3.1.1 | **Contratación de servicios de apoyo a la gestión del programa (Gerenciamiento)** | 830d | 2017-08-16 | 2021-01-18 |  | 87d |  | 875,000 |
| 502 | 1.3.1.1.1 | Ejecución año 1 | 110d | 2017-08-16 | 2018-01-31 | 600FS+66d | 87d | 0d | 125,000 |
| 503 | 1.3.1.1.2 | Ejecución año 2 | 230d | 2018-02-15 | 2019-01-25 | 502FS+10d | 87d | 0d | 220,000 |
| 504 | 1.3.1.1.3 | Ejecución año 3 | 230d | 2019-02-11 | 2020-01-21 | 503FS+10d | 87d | 0d | 250,000 |
| 505 | 1.3.1.1.4 | Ejecución año 4 | 230d | 2020-02-05 | 2021-01-18 | 504FS+10d | 87d |  | 280,000 |
| 506 | 1.3.1.2 | **Monitoreo y Evaluación** | 154d | 2020-05-25 | 2021-01-11 |  | 92d |  | 50,000 |
| 507 | 1.3.1.2.1 | **Proceso de Contratación Evaluación Final y Monitoreo del programa** | 86d | 2020-05-25 | 2020-09-22 |  | 92d |  |  |
| 508 | 1.3.1.2.1.1 | Elaboración de TdeR y de presupuesto | 15d | 2020-05-25 | 2020-06-12 | 30, 89, 53 | 92d | 0d |  |
| 509 | 1.3.1.2.1.2 | Revisión interna de TdeR y Presupuesto | 5d | 2020-06-15 | 2020-06-19 | 508 | 92d | 0d |  |
| 510 | 1.3.1.2.1.3 | Solicitud de no objeción al BID | 2d | 2020-06-22 | 2020-06-23 | 509 | 92d | 0d |  |
| 511 | 1.3.1.2.1.4 | No objeción del BID | 5d | 2020-06-24 | 2020-06-30 | 510 | 92d | 0d |  |
| 512 | 1.3.1.2.1.5 | Presentación de hojas de vida | 15d | 2020-07-01 | 2020-07-21 | 511 | 92d | 0d |  |
| 513 | 1.3.1.2.1.6 | Evaluación y calificación de hojas de vida | 15d | 2020-07-22 | 2020-08-11 | 512 | 92d | 0d |  |
| 514 | 1.3.1.2.1.7 | Solicitud de no objeción del BID | 2d | 2020-08-12 | 2020-08-13 | 513 | 92d | 0d |  |
| 515 | 1.3.1.2.1.8 | No objeción del BID | 5d | 2020-08-14 | 2020-08-20 | 514 | 92d | 0d |  |
| 516 | 1.3.1.2.1.9 | Negociación del contrato | 15d | 2020-08-21 | 2020-09-10 | 515 | 92d | 0d |  |
| 517 | 1.3.1.2.1.10 | Suscripción del contrato | 5d | 2020-09-11 | 2020-09-18 | 516 | 92d | 0d |  |
| 518 | 1.3.1.2.1.11 | Envío de contrato firmado al BID | 2d | 2020-09-21 | 2020-09-22 | 517 | 160d |  |  |
| 519 | 1.3.1.2.1.12 | Orden de Inicio | 2d | 2020-09-21 | 2020-09-22 | 517 | 92d | 0d |  |
| 520 | 1.3.1.2.2 | Ejecucion de la Consultoría | 66d | 2020-09-23 | 2021-01-07 | 519 | 92d | 0d |  |

| ID | WBS | Task | Duration | Start | Finish | Predecessors | Total slack | Cost |
| --- | --- | --- | --- | --- | --- | --- | --- | --- |
| 521 | 1.3.1.2.3 | **Pagos** | 68d | 2020-09-23 | 2021-01-11 |  | 92d | 50,000 |
| 522 | 1.3.1.2.3.1 | Primer Pago | 2d | 2020-09-23 | 2020-09-24 | 519 | 158d | 25,000 |
| 523 | 1.3.1.2.3.2 | Segundo Pago | 2d | 2021-01-08 | 2021-01-11 | 520 | 92d | 25,000 |
| 524 | 1.3.1.3 | **Auditoria** | 883d | 2017-10-11 | 2021-05-19 |  | 0d | 75,000 |
| 525 | 1.3.1.3.1 | **Proceso de contratación** | 101d | 2017-10-11 | 2018-03-07 |  | 0d |  |
| 526 | 1.3.1.3.1.1 | Preparación de documentos de licitación | 22d | 2017-10-11 | 2017-11-09 | 600FS+100d | 0d |  |
| 527 | 1.3.1.3.1.2 | Solicitud de No Objeción al BID | 2d | 2017-11-10 | 2017-11-13 | 526 | 0d |  |
| 528 | 1.3.1.3.1.3 | No Objeción del BID | 5d | 2017-11-14 | 2017-11-20 | 527 | 0d |  |
| 529 | 1.3.1.3.1.4 | Convocatoria pública a participar | 2d | 2017-11-21 | 2017-11-22 | 528 | 0d |  |
| 530 | 1.3.1.3.1.5 | Preparacion de ofertas | 22d | 2017-11-23 | 2017-12-22 | 529 | 0d |  |
| 531 | 1.3.1.3.1.6 | Recepción de ofertas y apertura | 1d | 2018-01-01 | 2018-01-01 | 530 | 0d |  |
| 532 | 1.3.1.3.1.7 | Evaluación de ofertas | 15d | 2018-01-02 | 2018-01-22 | 531 | 0d |  |
| 533 | 1.3.1.3.1.8 | Solicitud de No Objeción al BID(Informe de Evaluación) | 2d | 2018-01-23 | 2018-01-24 | 532 | 0d |  |
| 534 | 1.3.1.3.1.9 | No Objeción del BID | 5d | 2018-01-25 | 2018-01-31 | 533 | 0d |  |
| 535 | 1.3.1.3.1.10 | Notificación a oferentes y negociación de contrato | 2d | 2018-02-01 | 2018-02-02 | 534 | 0d |  |
| 536 | 1.3.1.3.1.11 | Solicitud no objeción al BID al borrador del contrato | 15d | 2018-02-05 | 2018-02-23 | 535 | 0d |  |
| 537 | 1.3.1.3.1.12 | No Objeción del BID | 5d | 2018-02-26 | 2018-03-02 | 536 | 0d |  |
| 538 | 1.3.1.3.1.13 | Suscripción del contrato | 2d | 2018-03-05 | 2018-03-06 | 537 | 0d |  |
| 539 | 1.3.1.3.1.14 | Envío de contrato firmado y registro PRISM al BID | 1d | 2018-03-07 | 2018-03-07 | 538 | 782d |  |
| 540 | 1.3.1.3.1.15 | Orden de Inicio | 1d | 2018-03-07 | 2018-03-07 | 538 | 0d |  |
| 541 | 1.3.1.3.2 | Auditoria anual 2017 | 40d | 2018-04-12 | 2018-06-07 | 540FS+20d | 0d |  |
| 542 | 1.3.1.3.3 | Auditoría intermedia 2018 | 40d | 2018-08-03 | 2018-09-27 | 541FS+40d | 0d |  |
| 543 | 1.3.1.3.4 | Auditoria anual 2018 | 40d | 2019-04-01 | 2019-06-03 | 542FS+120d | 0d |  |
| 544 | 1.3.1.3.5 | Auditoría intermedia 2019 | 40d | 2019-08-13 | 2019-10-11 | 543FS+50d | 0d |  |
| 545 | 1.3.1.3.6 | Auditoria anual 2019 | 40d | 2020-04-16 | 2020-06-11 | 544FS+120d | 0d |  |
| 546 | 1.3.1.3.7 | Auditoría intermedia 2020 | 40d | 2020-08-07 | 2020-10-02 | 545FS+40d | 0d |  |
| 547 | 1.3.1.3.8 | Auditoria anual 2020 | 20d | 2021-04-20 | 2021-05-17 | 546FS+130d | 0d |  |

| ID | WBS | Task | Duration | Start | Finish | Predecessors | Total slack | Free slack | Constraint | Cost |
| --- | --- | --- | --- | --- | --- | --- | --- | --- | --- | --- |
| 548 | 1.3.1.3.9 | **Pagos** | 722d | 2018-06-08 | 2021-05-19 |  | 0d |  |  | 75,000 |
| 549 | 1.3.1.3.9.1 | Auditoria anual 2017 | 2d | 2018-06-08 | 2018-06-11 | 541 | 720d |  |  | 10,700 |
| 550 | 1.3.1.3.9.2 | Auditoría intermedia 2018 | 2d | 2018-09-28 | 2018-10-08 | 542 | 640d |  |  | 10,700 |
| 551 | 1.3.1.3.9.3 | Auditoria anual 2018 | 2d | 2019-06-04 | 2019-06-05 | 543 | 480d |  |  | 10,700 |
| 552 | 1.3.1.3.9.4 | Auditoría intermedia 2019 | 2d | 2019-10-14 | 2019-10-15 | 544 | 390d |  |  | 10,700 |
| 553 | 1.3.1.3.9.5 | Auditoria anual 2019 | 2d | 2020-06-12 | 2020-06-15 | 545 | 230d |  |  | 10,700 |
| 554 | 1.3.1.3.9.6 | Auditoría intermedia 2020 | 2d | 2020-10-12 | 2020-10-13 | 546 | 150d |  |  | 10,700 |
| 555 | 1.3.1.3.9.7 | Auditoria anual 2020 | 2d | 2021-05-18 | 2021-05-19 | 547 | 0d |  |  | 10,800 |
| 556 | 1.4 | **CONDICIONES CONTRACTUALES** | 903d | 2017-05-16 | 2021-01-27 |  | 80d |  |  |  |
| 557 | 1.4.1 | **Informes Semestrales** | 891d | 2017-06-01 | 2021-01-27 |  | 80d |  |  |  |
| 558 | 1.4.1.1 | Informe primer semestre 2017 | 22d | 2017-06-01 | 2017-06-30 |  | 80d | 0d | start no earlier than 2017-06-01 |  |
| 559 | 1.4.1.2 | Informe segundo semestre 2017 | 22d | 2018-01-02 | 2018-01-31 | 558FS+120d | 80d | 0d |  |  |
| 560 | 1.4.1.3 | Informe primer semestre 2018 | 22d | 2018-05-25 | 2018-06-25 | 559FS+75d | 80d | 0d |  |  |
| 561 | 1.4.1.4 | Informe segundo semestre 2018 | 22d | 2018-12-18 | 2019-01-24 | 560FS+120d | 80d | 0d |  |  |
| 562 | 1.4.1.5 | Informe primer semestre 2019 | 22d | 2019-05-27 | 2019-06-25 | 561FS+80d | 80d | 0d |  |  |
| 563 | 1.4.1.6 | Informe segundo semestre 2019 | 22d | 2019-12-17 | 2020-01-24 | 562FS+120d | 80d | 0d |  |  |
| 564 | 1.4.1.7 | Informe primer semestre 2020 | 22d | 2020-05-27 | 2020-06-25 | 563FS+80d | 80d | 0d |  |  |
| 565 | 1.4.1.8 | Informe segundo semestre 2020 | 22d | 2020-12-21 | 2021-01-27 | 564FS+120d | 80d |  |  |  |
| 566 | 1.4.2 | **POA Anuales** | 669d | 2017-05-16 | 2020-02-07 |  | 314d |  |  |  |
| 567 | 1.4.2.1 | POA 2017 | 10d | 2017-05-16 | 2017-05-29 | 600 | 973d |  |  |  |
| 568 | 1.4.2.2 | POA 2018 | 10d | 2018-02-01 | 2018-02-14 | 559 | 797d |  |  |  |
| 569 | 1.4.2.3 | POA 2019 | 10d | 2019-01-25 | 2019-02-07 | 561 | 558d |  |  |  |
| 570 | 1.4.2.4 | POA 2020 | 10d | 2020-01-27 | 2020-02-07 | 563 | 314d |  |  |  |
| 571 | 1.4.3 | **Plan de Adquisiciones** | 669d | 2017-05-16 | 2020-02-07 |  | 314d |  |  |  |
| 572 | 1.4.3.1 | Plan de adquisiciones actualizado 2017 | 10d | 2017-05-16 | 2017-05-29 | 600 | 973d |  |  |  |
| 573 | 1.4.3.2 | Plan de adquisiciones actualizado 2018 | 10d | 2018-02-01 | 2018-02-14 | 559 | 797d |  |  |  |
| 574 | 1.4.3.3 | Plan de adquisiciones actualizado 2019 | 10d | 2019-01-25 | 2019-02-07 | 561 | 558d |  |  |  |
| 575 | 1.4.3.4 | Plan de adquisiciones actualizado 2020 | 10d | 2020-01-27 | 2020-02-07 | 563 | 314d |  |  |  |

| ID | WBS | Task | Type | Duration | Start | Finish | Predecessors | Total slack | Free slack | Constraint |
| --- | --- | --- | --- | --- | --- | --- | --- | --- | --- | --- |
| 576 | 1.5 | **FORMALIZACIÓN DEL CONTRATO DE PRÉSTAMO HO-L1121** |  | 159d | 2016-10-10 | 2017-06-02 |  | 0d |  |  |
| 577 | 1.5.1 | Negociación de contrato |  | 2d | 2016-10-10 | 2016-10-11 |  | 0d |  | start no earlier than 2016-10-10 |
| 578 | 1.5.2 | Aprobación del Contrato por parte del Directorio del BID |  | 31d | 2016-10-12 | 2016-11-23 | 577 | 0d |  |  |
| 579 | 1.5.3 | Solicitud de autorización para firmar al Congreso |  | 13d | 2016-11-24 | 2016-12-12 | 578 | 0d |  |  |
| 580 | 1.5.4 | Firma del contrato de préstamo |  | 2d | 2016-12-13 | 2016-12-14 | 579 | 0d |  |  |
| 581 | 1.5.5 | Aprobación del Contrato de Préstamo por el Congreso Nacional |  | 10d | 2016-12-15 | 2017-01-04 | 580 | 0d |  |  |
| 582 | 1.5.6 | Envío de contrato firmado al Poder Ejecutivo |  | 1d | 2017-01-05 | 2017-01-05 | 581 | 0d |  |  |
| 583 | 1.5.7 | Sanción del contrato por el Poder Ejecutivo |  | 2d | 2017-01-06 | 2017-01-09 | 582 | 0d |  |  |
| 584 | 1.5.8 | Ratificación del contrato por el Poder Ejecutivo |  | 17d | 2017-02-07 | 2017-03-01 | 583FS+20d | 0d |  |  |
| 585 | 1.5.9 | Envío de Contrato a publicación |  | 2d | 2017-03-02 | 2017-03-03 | 584 | 0d |  |  |
| 586 | 1.5.10 | Publicación en La Gaceta |  | 2d | 2017-03-06 | 2017-03-07 | 585 | 0d |  |  |
| 587 | 1.5.11 | Vigencia del Contrato de Préstamo | milestone | 0d | 2017-03-07 | 2017-03-07 | 586 | 53d | 0d |  |
| 588 | 1.5.12 | Envío de Gaceta a SEFIN |  | 9d | 2017-03-08 | 2017-03-20 | 587 | 993d | 0d |  |
| 589 | 1.5.13 | Elaboración de Dictamen Jurídico |  | 24d | 2017-03-21 | 2017-04-28 | 588 | 993d | 0d |  |
| 590 | 1.5.14 | **CONDICIONES PREVIAS AL PRIMER DESEMBOLSO** |  | 121d | 2016-12-01 | 2017-06-02 |  | 64d |  |  |
| 591 | 1.5.14.1 | **Condiciones generales** |  | 57d | 2017-03-08 | 2017-06-02 |  | 969d |  |  |
| 592 | 1.5.14.1.1 | Envío de Informe Jurídico al BID | milestone | 0d | 2017-04-28 | 2017-04-28 | 589 | 993d |  |  |
| 593 | 1.5.14.1.2 | Designar firmas de funcionarios responsables |  | 24d | 2017-03-08 | 2017-04-17 | 586 | 969d | 0d |  |
| 594 | 1.5.14.1.3 | Entrega de información sobre cuenta bancaría para desembolsos |  | 13d | 2017-04-18 | 2017-05-05 | 593 | 969d | 0d |  |
| 595 | 1.5.14.1.4 | Sistema de información y control financiero interno |  | 20d | 2017-05-08 | 2017-06-02 | 594 | 969d |  |  |
| 596 | 1.5.14.2 | **Condicionales especiales** |  | 107d | 2016-12-01 | 2017-05-15 |  | 0d |  |  |
| 597 | 1.5.14.2.1 | Manual operativo |  | 20d | 2016-12-01 | 2017-01-04 |  | 66d |  | start no earlier than 2016-12-01 |
| 598 | 1.5.14.2.2 | Incorporación de programa en el SIAFI y UEPEX |  | 22d | 2017-03-08 | 2017-04-06 | 586 | 0d |  |  |
| 599 | 1.5.14.2.3 | No Objeción del Banco |  | 11d | 2017-04-07 | 2017-04-28 | 598, 597 | 0d |  |  |
| 600 | 1.5.14.2.4 | Fecha de primer desembolso |  | 10d | 2017-05-02 | 2017-05-15 | 599 | 0d |  |  |
| 601 | 1.6 | Fecha ultimo desembolso BID | milestone | 0d | 2021-03-05 | 2021-03-05 | 587FS+973d | 53d |  |  |
